# HUARA III-2

Schedule from Primavera P6, 2024-06-13 to 2025-10-05, data date 2024-06-13, costs in USD.
Must finish by 2025-10-06

## Calendars

- Puente Pardo: Mon-Sun 08:00-16:00.

## Resources

| Resource | Group | Unit | Rate |
| --- | --- | --- | --- |
| Excavator | labor |  | 70 |
| HH | labor |  |  |
| MONEDA | material |  | 1 |
| Grava para drenaje | material |  |  |
| Relleno mejorado con Cemento | material |  |  |
| Geotextil | material |  |  |
| Roca | material | m3 |  |
| Cerco | material |  |  |
| Relleno estructural | material |  |  |
| CONCRETO PREMEZCLADO F'C=100 kg/cm2 CON CEMENTO T-I | material |  |  |
| CONCRETO PREMEZCLADO F'C=280 kg/cm2 CON CEMENTO T-I | material |  |  |
| PIEDRA CHANCADA | material |  |  |
| ARENA GRUESA | material |  |  |
| CEMENTO PORTLAND TIPO I (42.5 kg) | material |  |  |
| MADERA TORNILLO | material | und |  |
| acero | material |  |  |
| PINTURA ASFALTICA | material |  |  |
| Petroleo | material | gln |  |

## Schedule

| ID | WBS | Activity | Type | Duration | Start | Finish | Predecessors | Total float | Free float | Resources |
| --- | --- | --- | --- | --- | --- | --- | --- | --- | --- | --- |
|  | 3 | **HITOS** |  |  | 2024-06-13 | 2025-10-05 |  |  |  |  |
| A4720 |  | Inicio de Obra-Acceso al sitio | milestone | 0d | 2024-06-13 | 2024-06-13 |  | 0d |  |  |
| A4730 |  | Iinicio de Obras Preliminares | milestone | 0d | 2024-07-04 | 2024-07-04 | A4720 FS+21d | 0d |  |  |
| A4740 |  | Inicio de Obras - Diques Paquete 4 | milestone | 0d | 2024-08-01 | 2024-08-01 | A4730 FS+28d | 15d |  |  |
| A4760 |  | Inicio de Obras - Muros Reforzados | milestone | 0d | 2024-08-01 | 2024-08-01 | A4730 FS+28d | 431d |  |  |
| A4770 |  | Fin de Obras - Muros Reforzados | milestone | 0d | 2025-09-29 | 2025-09-29 | A7350 FF, A7570 FF, A7630 FF, A7650 FF, A7750 FF, A7450 FF, A5470 FF | 6d |  |  |
| A4750 |  | Fin de Obras - Diques Paquete 4 | milestone | 0d | 2025-10-05 | 2025-10-05 | A7830 FF, A7840 FF, A7860 FF, A7870 FF, A7310 FF, A7330 FF, A7370 FF, A7470 FF, A7490 FF, A7510 FF, A7530 FF, A7550 FF, A7590 FF, A7610 FF, A7670 FF, A7690 FF, A7710 FF, A7730 FF, A7770 FF, A7790 FF, A7390 FF, A7410 FF, A7430 FF, A7951 FF, A7952 FF, A7961 FF, A7960 FF, A2420 FF | 0d |  |  |
| A4780 |  | Culminación de Obras | milestone | 0d | 2025-10-05 | 2025-10-05 | A4770, A5380 FF, A5420 FF, A5440 FF, A5520 FF, A5570 FF, A7880 FF | 0d |  |  |
|  | 1 | **OBRAS PROVISIONALES** |  |  | 2024-06-16 | 2025-10-05 |  |  |  |  |
| A5380 |  | Campamento provisional de obra |  | 30d | 2024-07-04 | 2024-08-02 | A4730 SS | 429d |  | HH [240 h] |
| A5420 |  | Mantenimiento de caminos de acceso |  | 449d | 2024-07-04 | 2025-09-25 | A4730 SS, A5390 | 10d |  | HH [3592 h]; Petroleo [791935 gln] |
|  | 1 | **Obras Provisionales 2024** |  |  | 2024-06-16 | 2025-01-13 |  |  |  |  |
| A5390 |  | Movilizacion de maquinaria pesada |  | 15d | 2024-06-16 | 2024-06-30 | A4720 SS+3d | 13d | 0d | HH [120 h] |
| A7890 |  | Desviación y encauzamiento del río |  | 179d | 2024-07-04 | 2024-12-29 | A4730 SS, A5390 | 265d | 0d | HH [3592 h] |
| A5410 |  | Limpieza manual de material vegetal y de residuos |  | 166d | 2024-07-06 | 2024-12-18 | A4730 SS, A5390 FS+5d | 291d | 0d | HH [1328 h] |
| A5430 |  | Habilitacion de plataformas |  | 20d | 2024-07-09 | 2024-07-28 | A5390 FS+8d, A4730 SS | 280d | 0d | HH [160 h] |
| A5440 |  | Cruces de rio |  | 20d | 2024-07-11 | 2024-07-30 | A5410 SS+5d, A4730 SS | 432d |  | HH [96 h] |
| A5400 |  | Mejoramiento y habilitación de caminos de acceso |  | 170d | 2024-07-13 | 2024-12-29 | A4730 SS, A5390, A5430 SS+4d | 280d | 0d | HH [1152 h] |
| A5520 |  | Desbroce en areas auxiliares |  | 30d | 2024-07-13 | 2024-08-11 | A5400 SS, A4730 SS | 420d |  | HH [240 h] |
| A5570 |  | Desmovilizacion de maquinaria pesada |  | 15d | 2024-12-30 | 2025-01-13 | A6200, A7890 | 265d |  | HH [120 h] |
|  | 2 | **Obras Provisionales 2025** |  |  | 2025-04-16 | 2025-10-05 |  |  |  |  |
| A7820 |  | Movilizacion de maquinaria pesada |  | 15d | 2025-04-16 | 2025-04-30 | A5370 SS+105d | 4d | 0d | HH [120 h] |
| A7900 |  | Desviación y encauzamiento del río |  | 166d | 2025-04-16 | 2025-09-28 | A5370 SS+105d | 7d |  | HH [3592 h] |
| A7830 |  | Mejoramiento y habilitación de caminos de acceso |  | 167d | 2025-04-18 | 2025-10-01 | A7820 SS, A7850 SS | 4d |  | HH [1168 h] |
| A7850 |  | Habilitacion de plataformas |  | 20d | 2025-04-18 | 2025-05-07 | A7820 SS+2d | 4d | 0d | HH [160 h] |
| A7860 |  | Cruces de rio |  | 13d | 2025-04-18 | 2025-04-30 | A7820 SS+2d | 158d |  | HH [96 h] |
| A7840 |  | Limpieza manual de material vegetal y de residuos |  | 148d | 2025-04-21 | 2025-09-15 | A7820 SS+5d | 20d |  | HH [1184 h] |
| A7870 |  | Desbroce en areas auxiliares |  | 30d | 2025-04-21 | 2025-05-20 | A7820 SS+5d | 138d |  | HH [240 h] |
| A7880 |  | Desmovilizacion de maquinaria pesada |  | 18d | 2025-09-18 | 2025-10-05 | A4700 SF, A7960 FF, A7550 FF+5d, A7630 FF+6d, A7790 FF+5d, A7690 FF+5d, A7900 FF | 0d |  | HH [144 h] |

| ID | WBS | Activity | Type | Duration | Start | Finish | Predecessors | Total float | Free float | Resources | Cost |
| --- | --- | --- | --- | --- | --- | --- | --- | --- | --- | --- | --- |
|  | 2 | **DIQUES Y MUROS** |  |  | 2024-06-18 | 2025-10-05 |  |  |  |  |  |
|  | 29 | **CONSTRUCCION DIQUES 2024** |  |  | 2024-06-18 | 2024-12-31 |  |  |  |  |  |
| A7950 |  | Trabajos en cantera |  | 196d | 2024-06-18 | 2024-12-30 | A4720 SS+5d | 0d |  |  |  |
| A7951 |  | Suministro de Roca |  | 124d | 2024-08-30 | 2024-12-31 | A4730 SS+57d | 0d |  |  |  |
| A7952 |  | Suministro de Roca Nueva |  | 124d | 2024-08-30 | 2024-12-31 | A4730 SS+57d | 0d |  |  |  |
|  | 1 | **D-06-DI** |  |  | 2024-08-16 | 2024-10-15 |  |  |  |  |  |
| A7300 |  | Inicio D-06-DI - 58+217.72 - Entrega de terreno liberado | milestone | 0d | 2024-08-16 | 2024-08-16 | A4740 SS, A7950 SS+59d | 0d |  |  |  |
| A7310 |  | Fin D-06-DI - 58+217.72 - Entrega de terreno liberado | milestone | 0d | 2024-10-15 | 2024-10-15 | A5780 FF, A1230 FF, A5800 FF | 77d |  |  |  |
|  | 1 | **DIQUE** |  |  | 2024-08-16 | 2024-10-15 |  |  |  |  |  |
| A5580 |  | Solucion de interferencias INT-01 INT-02 INT-03 - Tipo tubo |  | 15d | 2024-08-18 | 2024-09-01 | A1000 SS+2d | 21d |  | HH [120 h] |  |
| A7270 |  | Solucion de interferencias D-06-DI-CAN01 D-06-DI-CAN02 D-06-DI-CAN03- Tipo canal |  | 15d | 2024-09-02 | 2024-09-16 | A1000 FS+13d | 6d | 0d | HH [120 h] |  |
|  | 1 | **Excavaciones** |  |  | 2024-08-16 | 2024-10-15 |  |  |  |  |  |
| A1000 |  | Desbroce |  | 4d | 2024-08-16 | 2024-08-19 | A7300 SS | 0d |  | Excavator [32 h]; HH [32 h] | 2,240 |
| A1010 |  | Excavacion de cimentacion |  | 33d | 2024-08-20 | 2024-09-21 | A1000 | 0d |  | Excavator [256 h]; HH [264 h] | 17,920 |
| A1020 |  | Perfilado y conformación de plataforma de fundación |  | 13d | 2024-09-08 | 2024-09-20 | A1010 SS+19d | 1d |  | HH [104 h] |  |
| A1030 |  | Excavacion de uña |  | 24d | 2024-09-22 | 2024-10-15 | A1010, A1020 | 0d |  | Excavator [184 h]; HH [192 h] | 12,880 |
|  | 2 | **Rellenos** |  |  | 2024-08-21 | 2024-09-30 |  |  |  |  |  |
| A1040 |  | Relleno con material granular (incluye extracción de material, zarandeo y / combinación de material) |  | 33d | 2024-08-21 | 2024-09-22 | A1010 SS+1d | 14d | 0d | HH [264 h]; MONEDA [14826.5] | 14,826.53 |
| A1210 |  | Perfilado de talud del dique |  | 17d | 2024-08-23 | 2024-09-08 | A1040 SS+2d | 14d |  | HH [136 h] |  |
| A1220 |  | Grava para drenaje |  | 13d | 2024-08-23 | 2024-09-04 | A1040 SS+2d | 18d |  | HH [104 h]; Grava para drenaje [810.46] |  |
| A1230 |  | Relleno mejorado con cemento |  | 8d | 2024-09-23 | 2024-09-30 | A1040 | 92d | 15d | HH [64 h]; Relleno mejorado con Cemento [639] |  |
|  | 3 | **Geotextil** |  |  | 2024-08-31 | 2024-09-23 |  |  |  |  |  |
| A1250 |  | Zanja de anclaje |  | 6d | 2024-08-31 | 2024-09-05 | A1040 SS+10d | 29d | 0d | HH [48 h] |  |
| A1240 |  | Instalación de geotextil 400 gr/m2 |  | 23d | 2024-09-01 | 2024-09-23 | A1250 SS+1d | 29d | 0d | HH [184 h]; Geotextil [13483] |  |

| ID | WBS | Activity | Type | Duration | Start | Finish | Predecessors | Total float | Free float | Resources | Cost |
| --- | --- | --- | --- | --- | --- | --- | --- | --- | --- | --- | --- |
|  | 4 | **Colocación de roca** |  |  | 2024-09-10 | 2024-10-15 |  |  |  |  |  |
| A1260 |  | Colocación de roca en uña |  | 13d | 2024-09-10 | 2024-09-22 | A1010 SS+21d | 0d |  | Excavator [104 h]; HH [104 h]; Roca [9352.25 m3] | 7,280 |
| A1270 |  | Colocación de roca en talud |  | 23d | 2024-09-23 | 2024-10-15 | A1260, A1210, A1220, A5580, A7270, A1030 FF | 0d |  | Excavator [184 h]; HH [184 h]; Roca [7644.31 m3] | 12,880 |
|  | 5 | **Transporte** |  |  | 2024-08-16 | 2024-10-15 |  |  |  |  |  |
| A5750 |  | Transporte de material orgánico (a dmo) |  | 5d | 2024-08-16 | 2024-08-20 | A1000 SS | 86d | 0d | HH [40 h] |  |
| A5760 |  | Transporte de material excedente |  | 56d | 2024-08-21 | 2024-10-15 | A1010 SS, A5750 | 86d | 0d | HH [456 h] |  |
| A5770 |  | Transporte de material de prestamo (afirmado) |  | 41d | 2024-08-21 | 2024-09-30 | A1040 SS, A5760 SS | 86d | 0d | HH [328 h] |  |
| A5790 |  | Transporte de material de préstamo cantera de rio (cuerpo de terraplén) |  | 41d | 2024-08-21 | 2024-09-30 | A1040 SS, A5770 SS | 86d | 0d | HH [328 h] |  |
| A5780 |  | Transporte de roca |  | 36d | 2024-09-10 | 2024-10-15 | A1240 SS+9d | 29d | 0d | HH [296 h] |  |
| A5800 |  | Transporte de material seleccionado para zanja |  | 6d | 2024-10-01 | 2024-10-06 | A1250 SS, A5790 | 86d | 9d | HH [48 h] |  |
|  | 3 | **D-04-PT** |  |  | 2024-10-16 | 2024-12-31 |  |  |  |  |  |
| A7380 |  | Inicio D-04-PT-61+080.84 - Entrega de terreno liberado | milestone | 0d | 2024-10-16 | 2024-10-16 | A1270 | 0d |  |  |  |
| A7390 |  | Fin D-04-PT-61+080.84 - Entrega de terreno liberado | milestone | 0d | 2024-12-31 | 2024-12-31 | A1530 FF, A5910 FF, A1490 FF, A6000 FF, A6020 FF | 0d |  |  |  |
|  | 1 | **DIQUE** |  |  | 2024-10-16 | 2024-12-31 |  |  |  |  |  |
| A5590 |  | Solucion de interferencias INT 01 INT 01 TL-01 - Tipo tubo |  | 20d | 2024-10-23 | 2024-11-11 | A1420, A7280 | 27d |  | HH [160 h] |  |
| A5910 |  | Solucion de interferencias D-04-PT-CAN01 D-04-PT-CAN02 - Tipo canal |  | 20d | 2024-11-02 | 2024-11-21 | A1420 FS+13d | 40d |  | HH [160 h] |  |
|  | 1 | **Excavaciones** |  |  | 2024-10-16 | 2024-12-14 |  |  |  |  |  |
| A1420 |  | Desbroce |  | 4d | 2024-10-16 | 2024-10-19 | A7380 SS | 0d |  | Excavator [32 h]; HH [32 h] | 2,240 |
| A1430 |  | Excavacion de cimentación |  | 43d | 2024-10-20 | 2024-12-01 | A1420 | 0d |  | Excavator [344 h]; HH [344 h] | 24,080 |
| A1440 |  | Perfilado y conformación de plataforma de fundación |  | 31d | 2024-11-01 | 2024-12-01 | A1430 SS+12d | 7d | 0d | HH [248 h] |  |
| A1450 |  | Excavacion de uña |  | 13d | 2024-12-02 | 2024-12-14 | A1430, A1440 | 7d |  | Excavator [104 h]; HH [104 h] | 7,280 |
|  | 2 | **Rellenos** |  |  | 2024-11-05 | 2024-11-17 |  |  |  |  |  |
| A1460 |  | Relleno con material granular (incluye extracción de material, zarandeo y / combinación de material) |  | 3d | 2024-11-05 | 2024-11-07 | A1430 SS+16d | 28d | 0d | HH [24 h]; MONEDA [1783.6] | 1,783.6 |
| A1470 |  | Perfilado de talud del dique |  | 4d | 2024-11-08 | 2024-11-11 | A1460 | 44d | 0d | HH [32 h] |  |
| A1480 |  | Relleno con material seleccionado (incluye extracción de material, / zarandeo y combinación de material) en sobreex |  | 10d | 2024-11-08 | 2024-11-17 | A1460, A1470 SS | 44d | 0d | HH [80 h]; Cerco [1700.2] |  |
| A1490 |  | Relleno mejorado con cemento |  | 8d | 2024-11-10 | 2024-11-17 | A1460 FS+2d, A1480 SS+2d | 44d |  | HH [64 h]; Relleno mejorado con Cemento [703] |  |

| ID | WBS | Activity | Type | Duration | Start | Finish | Predecessors | Total float | Free float | Resources | Cost |
| --- | --- | --- | --- | --- | --- | --- | --- | --- | --- | --- | --- |
|  | 3 | **Geotextil** |  |  | 2024-11-05 | 2024-11-22 |  |  |  |  |  |
| A1510 |  | Zanja de anclaje |  | 6d | 2024-11-05 | 2024-11-10 | A1460 SS | 28d | 0d | HH [48 h] |  |
| A1500 |  | Instalación de geotextil 400 gr/m2 |  | 12d | 2024-11-11 | 2024-11-22 | A1510 | 28d |  | HH [96 h]; Geotextil [14015] |  |
|  | 4 | **Colocacion de Roca** |  |  | 2024-11-17 | 2024-12-31 |  |  |  |  |  |
| A1520 |  | Colocación de roca en uña |  | 22d | 2024-11-17 | 2024-12-08 | A1430 SS+28d | 0d |  | Excavator [176 h]; HH [176 h]; Roca [10100.2 m3] | 12,320 |
| A1530 |  | Colocación de roca en talud |  | 23d | 2024-12-09 | 2024-12-31 | A1520, A1500 SS, A1450 SS, A5590 | 0d |  | Excavator [184 h]; HH [184 h]; Roca [7140.01 m3] | 12,880 |
|  | 5 | **Transporte** |  |  | 2024-10-16 | 2024-12-31 |  |  |  |  |  |
| A5990 |  | Transporte de material orgánico (a dmo) |  | 4d | 2024-10-16 | 2024-10-19 | A1420 SS, A5960, A5940 | 17d | 0d | HH [32 h] |  |
| A6000 |  | Transporte de material excedente |  | 56d | 2024-10-20 | 2024-12-14 | A1430 SS, A5990, A6010 FF | 17d |  | HH [448 h] |  |
| A6040 |  | Transporte de material seleccionado para zanja |  | 3d | 2024-11-05 | 2024-11-07 | A1510 SS | 45d | 0d | HH [24 h] |  |
| A6030 |  | Transporte de material de préstamo cantera de rio (cuerpo de terraplén) |  | 5d | 2024-11-08 | 2024-11-12 | A1460 SS+3d, A6040 | 45d | 0d | HH [40 h] |  |
| A6010 |  | Transporte de material de prestamo (afirmado) |  | 4d | 2024-11-13 | 2024-11-16 | A1460 SS+8d, A6030 | 45d | 28d | HH [32 h] |  |
| A6020 |  | Transporte de roca |  | 45d | 2024-11-17 | 2024-12-31 | A1520 SS | 0d |  | HH [360 h] |  |
|  | 5 | **I-15-2-DI - Muro** |  |  | 2024-08-21 | 2024-09-27 |  |  |  |  |  |
| A7340 |  | Inicio I-15-2-DI-68+726.84 - Entrega de terreno liberado | milestone | 0d | 2024-08-21 | 2024-08-21 | A4740 SS, A7950 SS+64d | 0d |  |  |  |
| A7350 |  | Fin I-15-2-DI-68+726.84 - Entrega de terreno liberado | milestone | 0d | 2024-09-27 | 2024-09-27 | A1700 FF, A1790 FF, A1810 FF | 0d |  |  |  |
|  | 1 | **DIQUE** |  |  | 2024-08-21 | 2024-09-27 |  |  |  |  |  |
|  | 1 | **Excavaciones** |  |  | 2024-08-21 | 2024-09-08 |  |  |  |  |  |
| A1680 |  | Desbroce |  | 1d | 2024-08-21 | 2024-08-21 | A7340 SS | 0d |  | Excavator [8 h]; HH [8 h] | 560 |
| A1690 |  | Excavacion de cimentación |  | 18d | 2024-08-22 | 2024-09-08 | A1680 | 0d |  | Excavator [144 h]; HH [144 h] | 10,080 |
|  | 4 | **Colocacion de Roca** |  |  | 2024-09-09 | 2024-09-15 |  |  |  |  |  |
| A1710 |  | Colocación de roca en uña |  | 6d | 2024-09-09 | 2024-09-14 | A1750, A1800 FS+7d, A1690 | 0d |  | Excavator [56 h]; HH [56 h]; Roca [1780.89 m3] | 3,920 |
| A1720 |  | Colocación de roca en talud |  | 1d | 2024-09-15 | 2024-09-15 | A1710 | 0d |  | Excavator [8 h]; HH [8 h]; Roca [267.77 m3] | 560 |
|  | 2 | **Rellenos** |  |  | 2024-09-16 | 2024-09-27 |  |  |  |  |  |
| A1700 |  | Relleno estructural |  | 12d | 2024-09-16 | 2024-09-27 | A1830, A1720 | 0d |  | HH [104 h]; Relleno estructural [4040] |  |

| ID | WBS | Activity | Type | Duration | Start | Finish | Predecessors | Total float | Free float | Resources | Cost |
| --- | --- | --- | --- | --- | --- | --- | --- | --- | --- | --- | --- |
|  | 5 | **Transporte** |  |  | 2024-08-21 | 2024-09-17 |  |  |  |  |  |
| A5870 |  | Transporte de material orgánico (a dmo) |  | 2d | 2024-08-21 | 2024-08-22 | A1680 SS | 37d | 0d | HH [16 h] |  |
| A5880 |  | Transporte de material excedente |  | 18d | 2024-08-23 | 2024-09-09 | A1690 SS, A5870 | 37d | 0d | HH [144 h] |  |
| A5890 |  | Transporte de material de prestamo (afirmado) |  | 8d | 2024-09-02 | 2024-09-09 | A5880 SS+10d | 37d | 0d | HH [64 h] |  |
| A5900 |  | Transporte de roca |  | 8d | 2024-09-10 | 2024-09-17 | A1710 SS, A5880, A5890 | 37d | 0d | HH [64 h] |  |
|  | 3 | **MURO** |  |  | 2024-08-21 | 2024-09-20 |  |  |  |  |  |
| A1730 |  | Concreto de nivelacion (f'c=100 kg/cm2) |  | 6d | 2024-08-21 | 2024-08-26 | A7340 SS | 1d | 0d | HH [48 h]; CONCRETO PREMEZCLADO F'C=100 kg/cm2 CON CEMENTO T-I [108] |  |
| A1760 |  | Encofrado y desencofrado caravista |  | 17d | 2024-08-21 | 2024-09-06 | A1770 SS | 4d | 3d | HH [136 h] |  |
| A1770 |  | Encofrado y desencofrado cara oculta |  | 19d | 2024-08-21 | 2024-09-08 | A7340 SS | 4d | 0d | HH [152 h]; MADERA TORNILLO [7358 und] |  |
| A1780 |  | Acero de refuerzo f'y=4200kg/cm2 |  | 26d | 2024-08-21 | 2024-09-15 | A7340 SS | 2d | 1d | HH [208 h]; acero [137972] |  |
| A1740 |  | Concreto clase c (f'c=280 kg/cm2) premezclado - cimientos reforzados |  | 18d | 2024-08-24 | 2024-09-10 | A1780 SS+2d, A1730 SS+3d, A1760 SS | 1d | 0d | HH [144 h]; CONCRETO PREMEZCLADO F'C=280 kg/cm2 CON CEMENTO T-I [758]; PIEDRA CHANCADA [782.89]; ARENA GRUESA [757.44]; CEMENTO PORTLAND TIPO I (42.5 kg) [12701.6] |  |
| A1750 |  | Concreto clase c (f'c=280 kg/cm2) premezclado - muros de contencion |  | 13d | 2024-08-24 | 2024-09-05 | A1740 SS | 1d | 0d | HH [104 h]; CONCRETO PREMEZCLADO F'C=280 kg/cm2 CON CEMENTO T-I [553] |  |
| A1800 |  | Geocompuesto de drenaje |  | 2d | 2024-08-27 | 2024-08-28 | A1730 | 4d |  | HH [16 h] |  |
| A1810 |  | Tubo pvc - d=6'' d=4'' |  | 6d | 2024-08-27 | 2024-09-01 | A1730 | 26d |  | HH [48 h] |  |
| A1790 |  | Pintura bituminosa |  | 15d | 2024-09-06 | 2024-09-20 | A1750 | 7d |  | HH [120 h]; PINTURA ASFALTICA [1727] |  |
| A1830 |  | Tunta de dilatación |  | 9d | 2024-09-06 | 2024-09-14 | A1750 | 1d |  | HH [72 h] |  |
|  | 2 | **D-05-DI** |  |  | 2024-09-08 | 2024-10-15 |  |  |  |  |  |
| A7360 |  | Inicio D-05-DI-59+855.20 - Entrega de terreno liberado | milestone | 0d | 2024-09-08 | 2024-09-08 | A4740 SS, A7950 SS+82d | 18d | 0d |  |  |
| A7370 |  | Fin D-05-DI-59+855.20 - Entrega de terreno liberado | milestone | 0d | 2024-10-15 | 2024-10-15 | A1410 FF, A1370 FF | 77d |  |  |  |
|  | 1 | **DIQUE** |  |  | 2024-09-08 | 2024-10-15 |  |  |  |  |  |
| A5600 |  | Solucion de interferencias INT 01 - Tipo tubo |  | 12d | 2024-09-17 | 2024-09-28 | A1280, A7270 | 27d | 0d | HH [96 h] |  |
| A5610 |  | Solucion de interferencias D-05-DI-CAN01 - Tipo canal |  | 12d | 2024-09-17 | 2024-09-28 | A1280 FS+8d | 29d | 4d | HH [96 h] |  |
|  | 1 | **Excavaciones** |  |  | 2024-09-08 | 2024-09-25 |  |  |  |  |  |
| A1280 |  | Desbroce |  | 1d | 2024-09-08 | 2024-09-08 | A7360 SS | 18d | 0d | Excavator [8 h]; HH [8 h] | 560 |
| A1290 |  | Excavacion de cimentación |  | 8d | 2024-09-09 | 2024-09-16 | A1280 | 18d | 0d | Excavator [64 h]; HH [64 h] | 4,480 |
| A1300 |  | Perfilado y conformación de plataforma de fundación |  | 3d | 2024-09-14 | 2024-09-16 | A1290 SS+5d | 33d | 3d | HH [24 h] |  |
| A1310 |  | Excavacion de uña |  | 9d | 2024-09-17 | 2024-09-25 | A1290, A1300 SS | 30d | 3d | Excavator [72 h]; HH [72 h] | 5,040 |

| ID | WBS | Activity | Type | Duration | Start | Finish | Predecessors | Total float | Free float | Resources | Cost |
| --- | --- | --- | --- | --- | --- | --- | --- | --- | --- | --- | --- |
|  | 2 | **Rellenos** |  |  | 2024-09-09 | 2024-09-25 |  |  |  |  |  |
| A1320 |  | Relleno con material granular (incluye extracción de material, zarandeo y / combinación de material) |  | 13d | 2024-09-09 | 2024-09-21 | A1290 SS | 33d | 0d | HH [104 h]; MONEDA [6152.9] | 6,152.9 |
| A1330 |  | Perfilado de talud del dique |  | 6d | 2024-09-16 | 2024-09-21 | A1320 SS+7d | 103d | 0d | HH [48 h] |  |
| A1340 |  | Relleno con material seleccionado (incluye extracción de material, / zarandeo y combinación de material) en sobreex |  | 2d | 2024-09-16 | 2024-09-17 | A1330 SS | 103d | 0d | HH [16 h]; Cerco [419.29] |  |
| A1350 |  | Grava para drenaje |  | 5d | 2024-09-18 | 2024-09-22 | A1320 SS, A1360 SS | 103d | 0d | HH [40 h]; Grava para drenaje [366.22] |  |
| A1360 |  | Relleno material propio compactado |  | 8d | 2024-09-18 | 2024-09-25 | A1340 | 103d | 0d | HH [64 h] |  |
| A1370 |  | Relleno mejorado con cemento |  | 2d | 2024-09-18 | 2024-09-19 | A1350 SS | 103d | 26d | HH [16 h]; Relleno mejorado con Cemento [227] |  |
|  | 3 | **Geotextil** |  |  | 2024-09-12 | 2024-09-21 |  |  |  |  |  |
| A1390 |  | Zanja de anclaje |  | 2d | 2024-09-12 | 2024-09-13 | A1320 SS+3d | 35d | 0d | HH [16 h] |  |
| A1380 |  | Instalación de geotextil 400 gr/m2 |  | 8d | 2024-09-14 | 2024-09-21 | A1390 | 39d | 12d | HH [64 h]; Geotextil [6481] |  |
|  | 4 | **Colocacion de Roca** |  |  | 2024-09-11 | 2024-10-15 |  |  |  |  |  |
| A1400 |  | Colocación de roca en uña |  | 15d | 2024-09-11 | 2024-09-25 | A1290 SS+2d | 18d | 0d | Excavator [120 h]; HH [120 h]; Roca [3585.86 m3] | 8,400 |
| A1410 |  | Colocación de roca en talud |  | 17d | 2024-09-29 | 2024-10-15 | A1400, A1380 SS+3d, A1310, A5600 | 27d | 0d | Excavator [136 h]; HH [136 h]; Roca [2819.15 m3] | 9,520 |
|  | 5 | **Transporte** |  |  | 2024-09-11 | 2024-10-14 |  |  |  |  |  |
| A5960 |  | Transporte de roca |  | 34d | 2024-09-11 | 2024-10-14 | A1400 SS | 18d | 1d | HH [272 h]; Roca [272 m3] |  |
| A5980 |  | Transporte de material seleccionado para zanja |  | 2d | 2024-09-12 | 2024-09-13 | A1390 SS | 35d | 2d | HH [16 h] |  |
| A5970 |  | Transporte de material de préstamo cantera de rio (cuerpo de terraplén) |  | 7d | 2024-09-16 | 2024-09-22 | A1320 SS+7d, A5980 | 33d | 0d | HH [56 h] |  |
| A5930 |  | Transporte de material orgánico (a dmo) |  | 1d | 2024-09-18 | 2024-09-18 | A1280 SS, A5900 | 37d | 4d | HH [8 h] |  |
| A5940 |  | Transporte de material excedente |  | 7d | 2024-09-23 | 2024-09-29 | A1290 SS, A5930, A5970 SS+7d | 33d | 16d | HH [56 h] |  |
|  | 4 | **I-15-1-DI** |  |  | 2024-09-28 | 2024-12-31 |  |  |  |  |  |
| A7320 |  | Inicio I-15-1-DI-67+628.33 - Entrega de terreno liberado | milestone | 0d | 2024-09-28 | 2024-09-28 | A7350 | 0d |  |  |  |
| A7330 |  | Fin I-15-1-DI-67+628.33 - Entrega de terreno liberado | milestone | 0d | 2024-12-31 | 2024-12-31 | A1670 FF, A1620 FF, A5820 FF, A5840 FF | 0d |  |  |  |
|  | 1 | **DIQUE** |  |  | 2024-09-28 | 2024-12-31 |  |  |  |  |  |
| A7250 |  | Solucion de interferencias INT 01 INT02 INT03 TL01 - Tipo tubo |  | 15d | 2024-10-03 | 2024-10-17 | A1540, A5610 | 25d |  | HH [120 h] |  |
| A7280 |  | Solucion de interferencias I-15-DI-CAN01 - Tipo canal |  | 10d | 2024-10-13 | 2024-10-22 | A1540 FS+10d | 27d | 0d | HH [80 h] |  |

| ID | WBS | Activity | Duration | Start | Finish | Predecessors | Total float | Free float | Resources | Cost |
| --- | --- | --- | --- | --- | --- | --- | --- | --- | --- | --- |
|  | 1 | **Excavaciones** |  | 2024-09-28 | 2024-11-20 |  |  |  |  |  |
| A1540 |  | Desbroce | 5d | 2024-09-28 | 2024-10-02 | A7320 SS | 0d |  | Excavator [40 h]; HH [40 h] | 2,800 |
| A1550 |  | Excavacion de cimentación | 24d | 2024-10-03 | 2024-10-26 | A1540 | 0d |  | Excavator [184 h]; HH [184 h] | 12,880 |
| A1560 |  | Perfilado y conformación de plataforma de fundación | 17d | 2024-10-09 | 2024-10-25 | A1550 SS+6d | 17d | 1d | HH [136 h] |  |
| A1570 |  | Excavacion de uña | 25d | 2024-10-27 | 2024-11-20 | A1550, A1560 | 16d |  | Excavator [168 h]; HH [168 h] | 11,760 |
|  | 2 | **Rellenos** |  | 2024-10-03 | 2024-10-21 |  |  |  |  |  |
| A1580 |  | Relleno con material granular (incluye extracción de material, zarandeo y / combinación de material) | 15d | 2024-10-03 | 2024-10-17 | A1550 SS | 23d | 0d | HH [120 h]; MONEDA [13880.9] | 13,880.91 |
| A1590 |  | Perfilado de talud del dique | 13d | 2024-10-06 | 2024-10-18 | A1580 SS+3d | 80d | 9d | HH [104 h] |  |
| A1610 |  | Relleno mejorado con cemento | 12d | 2024-10-08 | 2024-10-19 | A1580 SS+5d | 71d | 0d | HH [96 h]; Relleno mejorado con Cemento [999] |  |
| A1600 |  | Grava para drenaje | 5d | 2024-10-15 | 2024-10-19 | A1580 SS+12d, A1590 SS | 71d | 0d | HH [40 h]; Grava para drenaje [331.81] |  |
| A1620 |  | Relleno estructural | 2d | 2024-10-20 | 2024-10-21 | A1580 FS+1d, A1610, A1600 | 71d |  | HH [16 h]; Relleno estructural [215] |  |
|  | 3 | **Geotextil** |  | 2024-10-10 | 2024-11-08 |  |  |  |  |  |
| A1640 |  | Zanja de anclaje | 10d | 2024-10-10 | 2024-10-19 | A1580 SS+7d | 23d | 0d | HH [80 h] |  |
| A1630 |  | Instalación de geotextil 400 gr/m2 | 20d | 2024-10-20 | 2024-11-08 | A1640 | 23d |  | HH [160 h]; Geotextil [21616] |  |
|  | 4 | **Colocacion de Roca** |  | 2024-10-06 | 2024-12-31 |  |  |  |  |  |
| A1650 |  | Colocación de roca en uña | 37d | 2024-10-06 | 2024-11-11 | A1550 SS+3d | 0d |  | Excavator [288 h]; HH [288 h]; Roca [16805.8 m3] | 20,160 |
| A1660 |  | Colocación de roca en talud | 48d | 2024-11-12 | 2024-12-29 | A1650, A1570 SS, A1630 SS, A7250, A1410 | 0d |  | Excavator [376 h]; HH [376 h]; Roca [14772.1 m3] | 26,320 |
| A1670 |  | Colocación de roca en corona | 2d | 2024-12-30 | 2024-12-31 | A1660 | 0d |  | Excavator [8 h]; HH [8 h]; Roca [66 m3] | 560 |
|  | 5 | **Transporte** |  | 2024-09-28 | 2024-12-28 |  |  |  |  |  |
| A5810 |  | Transporte de material orgánico (a dmo) | 5d | 2024-09-28 | 2024-10-02 | A1540 SS | 43d | 0d | HH [40 h] |  |
| A5820 |  | Transporte de material excedente | 47d | 2024-10-03 | 2024-11-18 | A1550 SS, A5810, A5860 FF | 43d |  | HH [376 h] |  |
| A5830 |  | Transporte de material de prestamo (afirmado) | 19d | 2024-10-03 | 2024-10-21 | A1580 SS | 80d | 0d | HH [152 h] |  |
| A5850 |  | Transporte de material de préstamo cantera de rio (cuerpo de terraplén) | 19d | 2024-10-03 | 2024-10-21 | A1580 SS, A5830 SS | 80d | 7d | HH [152 h] |  |
| A5840 |  | Transporte de roca | 84d | 2024-10-06 | 2024-12-28 | A1650 SS, A5780 SS | 3d |  | HH [672 h] |  |
| A5860 |  | Transporte de material seleccionado para zanja | 10d | 2024-10-10 | 2024-10-19 | A1640 SS, A5850 SS | 73d | 30d | HH [80 h] |  |

| ID | WBS | Activity | Type | Duration | Start | Finish | Predecessors | Total float | Free float | Resources | Cost |
| --- | --- | --- | --- | --- | --- | --- | --- | --- | --- | --- | --- |
|  | 11 | **I-11-PT** |  |  | 2024-08-31 | 2024-11-05 |  |  |  |  |  |
| A7420 |  | Inicio I-11-PT-88+555.14 - Entrega de terreno liberado | milestone | 0d | 2024-08-31 | 2024-08-31 | A4740 SS, A7950 SS+74d | 0d |  |  |  |
| A7430 |  | Fin I-11-PT-88+555.14 - Entrega de terreno liberado | milestone | 0d | 2024-11-05 | 2024-11-05 | A2540 FF, A6160 FF | 56d |  |  |  |
|  | 1 | **DIQUE** |  |  | 2024-08-31 | 2024-11-05 |  |  |  |  |  |
| A5680 |  | Solucion de interferencias INT 01 INT 02 INT 03- Tipo tubo |  | 30d | 2024-09-01 | 2024-09-30 | A2430 SS+1d | 1d |  | HH [240 h] |  |
|  | 1 | **Excavaciones** |  |  | 2024-08-31 | 2024-10-13 |  |  |  |  |  |
| A2430 |  | Desbroce |  | 4d | 2024-08-31 | 2024-09-03 | A7420 SS | 0d |  | Excavator [32 h]; HH [32 h] | 2,240 |
| A2440 |  | Excavacion de cimentación |  | 20d | 2024-09-04 | 2024-09-23 | A2430 | 0d |  | Excavator [160 h]; HH [160 h] | 11,200 |
| A2450 |  | Perfilado y conformación de plataforma de fundación |  | 15d | 2024-09-08 | 2024-09-22 | A2440 SS+4d | 1d |  | HH [120 h] |  |
| A2460 |  | Excavacion de uña |  | 20d | 2024-09-24 | 2024-10-13 | A2440, A2450 | 0d |  | Excavator [160 h]; HH [160 h] | 11,200 |
|  | 2 | **Rellenos** |  |  | 2024-09-07 | 2024-10-01 |  |  |  |  |  |
| A2470 |  | Relleno con material granular (incluye extracción de material, zarandeo y / combinación de material) |  | 18d | 2024-09-07 | 2024-09-24 | A2440 SS+3d | 6d | 0d | HH [144 h]; MONEDA [8429.94] | 8,429.94 |
| A2490 |  | Relleno con material seleccionado (incluye extracción de material, / zarandeo y combinación de material) en sobreex |  | 19d | 2024-09-09 | 2024-09-27 | A2440 SS+5d | 1d | 0d | HH [152 h]; Cerco [3138.63] |  |
| A2480 |  | Perfilado de talud del dique |  | 15d | 2024-09-11 | 2024-09-25 | A2470 SS+4d | 6d | 5d | HH [120 h] |  |
| A2500 |  | Relleno mejorado con cemento |  | 15d | 2024-09-17 | 2024-10-01 | A2490 SS+8d | 1d | 0d | HH [120 h]; Relleno mejorado con Cemento [1256] |  |
|  | 3 | **Geotextil** |  |  | 2024-09-22 | 2024-10-25 |  |  |  |  |  |
| A2520 |  | Zanja de anclaje |  | 9d | 2024-09-22 | 2024-09-30 | A2500 SS+5d | 1d | 0d | HH [72 h] |  |
| A2510 |  | Instalación de geotextil 400 gr/m2 |  | 25d | 2024-10-01 | 2024-10-25 | A2520, A2480 | 1d |  | HH [200 h]; Geotextil [26283] |  |
|  | 4 | **Colocacion de Roca** |  |  | 2024-09-10 | 2024-11-05 |  |  |  |  |  |
| A2530 |  | Colocación de roca en uña |  | 22d | 2024-09-10 | 2024-10-01 | A2440 SS+6d | 0d |  | Excavator [176 h]; HH [176 h]; Roca [15569 m3] | 12,320 |
| A2540 |  | Colocación de roca en talud |  | 35d | 2024-10-02 | 2024-11-05 | A2530, A2510 SS, A2460 SS+8d, A5680 | 0d |  | Excavator [280 h]; HH [280 h]; Roca [17371.5 m3] | 19,600 |
|  | 5 | **Transporte** |  |  | 2024-09-07 | 2024-11-05 |  |  |  |  |  |
| A6130 |  | Transporte de material de prestamo (afirmado) |  | 8d | 2024-09-07 | 2024-09-14 | A2470 SS | 96d | 0d | HH [64 h] |  |
| A6140 |  | Transporte de roca |  | 57d | 2024-09-10 | 2024-11-05 | A2530 SS | 25d | 0d | HH [456 h] |  |
| A6150 |  | Transporte de material de préstamo cantera de rio (cuerpo de terraplén) |  | 8d | 2024-09-15 | 2024-09-22 | A2470 SS, A6130 | 96d | 0d | HH [64 h] |  |
| A6160 |  | Transporte de material seleccionado para zanja |  | 4d | 2024-09-23 | 2024-09-26 | A2520 SS, A6150 | 96d | 40d | HH [32 h] |  |

| ID | WBS | Activity | Type | Duration | Start | Finish | Predecessors | Total float | Free float | Resources | Cost |
| --- | --- | --- | --- | --- | --- | --- | --- | --- | --- | --- | --- |
|  | 14 | **I-08-DI - Muro** |  |  | 2024-11-06 | 2024-12-31 |  |  |  |  |  |
| A7440 |  | Inicio I-08-DI-108+225.70 - Entrega de terreno liberado | milestone | 0d | 2024-11-06 | 2024-11-06 | A2540 | 0d |  |  |  |
| A7450 |  | Fin I-08-DI-108+225.70 - Entrega de terreno liberado | milestone | 0d | 2024-12-31 | 2024-12-31 | A2930 FF, A2870 FF, A2880 FF, A4830 FF | 0d |  |  |  |
|  | 1 | **DIQUE** |  |  | 2024-11-06 | 2024-12-31 |  |  |  |  |  |
| A5710 |  | Solucion de interferencias |  | 33d | 2024-11-06 | 2024-12-08 | A2810 SS | 3d |  | HH [264 h] |  |
|  | 1 | **Excavaciones** |  |  | 2024-11-06 | 2024-11-30 |  |  |  |  |  |
| A2810 |  | Desbroce |  | 1d | 2024-11-06 | 2024-11-06 | A2540, A7440 SS | 0d |  | Excavator [8 h]; HH [8 h] | 560 |
| A2820 |  | Excavacion de cimentación |  | 8d | 2024-11-07 | 2024-11-14 | A2810 | 0d |  | Excavator [56 h]; HH [56 h] | 3,920 |
| A2830 |  | Perfilado y conformación de plataforma de fundación |  | 6d | 2024-11-09 | 2024-11-14 | A2820 SS+2d | 0d |  | HH [32 h] |  |
| A2840 |  | Excavacion de uña |  | 16d | 2024-11-15 | 2024-11-30 | A2820, A2830 | 0d |  | Excavator [128 h]; HH [128 h] | 8,960 |
|  | 2 | **Rellenos** |  |  | 2024-11-15 | 2024-12-13 |  |  |  |  |  |
| A2860 |  | Perfilado de talud del dique |  | 1d | 2024-11-15 | 2024-11-15 | A2820 | 45d | 2d | HH [8 h] |  |
| A2850 |  | Relleno con material granular (incluye extracción de material, zarandeo y / combinación de material) |  | 1d | 2024-11-17 | 2024-11-17 | A2820 FS+2d | 1d | 0d | HH [8 h]; MONEDA [208.14] | 208.14 |
| A2870 |  | Relleno mejorado con cemento |  | 1d | 2024-11-18 | 2024-11-18 | A2850, A2860 | 43d |  | HH [8 h]; Relleno mejorado con Cemento [131.72] |  |
| A2880 |  | Relleno estructural |  | 8d | 2024-12-06 | 2024-12-13 | A4890, A4850 | 18d |  | HH [64 h]; Relleno estructural [718] |  |
|  | 3 | **Geotextiles** |  |  | 2024-11-18 | 2024-11-29 |  |  |  |  |  |
| A2900 |  | Zanja de anclaje |  | 2d | 2024-11-18 | 2024-11-19 | A2850 | 1d | 0d | HH [16 h] |  |
| A2890 |  | Instalación de geotextil 400 gr/m2 |  | 10d | 2024-11-20 | 2024-11-29 | A2900 | 1d |  | HH [80 h]; Geotextil [7768] |  |
|  | 4 | **Colocacion de Roca** |  |  | 2024-12-01 | 2024-12-31 |  |  |  |  |  |
| A2910 |  | Colocación de roca en uña |  | 11d | 2024-12-01 | 2024-12-11 | A4850 SS+2d, A2890, A2840 | 0d |  | Excavator [80 h]; HH [80 h]; Roca [4350.81 m3] | 5,600 |
| A2920 |  | Colocación de roca en talud |  | 19d | 2024-12-12 | 2024-12-30 | A2910, A5710 | 0d |  | Excavator [152 h]; HH [144 h]; Roca [2986.31 m3] | 10,640 |
| A2930 |  | Colocación de roca en corona |  | 1d | 2024-12-31 | 2024-12-31 | A2920 | 0d |  | Excavator [8 h]; HH [8 h]; Roca [105.39 m3] | 560 |
|  | 5 | **Transporte** |  |  | 2024-11-06 | 2024-12-29 |  |  |  |  |  |
| A6170 |  | Transporte de material orgánico (a dmo) |  | 2d | 2024-11-06 | 2024-11-07 | A2810 SS, A6140 | 25d | 23d | HH [16 h] |  |
| A6220 |  | Transporte de material seleccionado para zanja |  | 2d | 2024-11-18 | 2024-11-19 | A2900 SS | 27d | 0d | HH [16 h] |  |
| A6210 |  | Transporte de material de préstamo cantera de rio (cuerpo de terraplén) |  | 15d | 2024-11-20 | 2024-12-04 | A2850 SS, A6220 | 27d | 25d | HH [120 h] |  |
| A6200 |  | Transporte de roca |  | 29d | 2024-12-01 | 2024-12-29 | A2910 SS, A6170, A6210 FF | 2d | 0d | HH [232 h] |  |

| ID | WBS | Activity | Type | Duration | Start | Finish | Predecessors | Total float | Free float | Resources | Cost |
| --- | --- | --- | --- | --- | --- | --- | --- | --- | --- | --- | --- |
|  | 5 | **MURO** |  |  | 2024-11-15 | 2024-12-05 |  |  |  |  |  |
| A4790 |  | Concreto de nivelacion (f'c=100 kg/cm2) |  | 2d | 2024-11-15 | 2024-11-16 | A2820 | 2d | 0d | HH [16 h]; CONCRETO PREMEZCLADO F'C=100 kg/cm2 CON CEMENTO T-I [36] |  |
| A4840 |  | Acero de refuerzo f'y=4200kg/cm2 |  | 11d | 2024-11-15 | 2024-11-25 | A2820 | 1d | 0d | HH [88 h]; acero [23586] |  |
| A4820 |  | Encofrado y desencofrado caravista |  | 8d | 2024-11-16 | 2024-11-23 | A4790 SS+1d | 31d | 0d | HH [64 h] |  |
| A4800 |  | Concreto clase c (f'c=280 kg/cm2) premezclado - cimientos reforzados |  | 9d | 2024-11-17 | 2024-11-25 | A4840 SS+2d | 1d | 0d | HH [72 h]; CONCRETO PREMEZCLADO F'C=280 kg/cm2 CON CEMENTO T-I [122.4]; PIEDRA CHANCADA [118.49]; ARENA GRUESA [114.64]; CEMENTO PORTLAND TIPO I (42.5 kg) [1922.44] |  |
| A4830 |  | Encofrado y desencofrado cara oculta |  | 11d | 2024-11-20 | 2024-11-30 | A4790 SS+4d, A4820 SS+4d | 31d |  | HH [88 h]; MADERA TORNILLO [1135 und] |  |
| A4810 |  | Concreto clase c (f'c=280 kg/cm2) premezclado - muros de contencion |  | 5d | 2024-11-23 | 2024-11-27 | A4790 FS+5d, A4800 SS+6d | 1d | 0d | HH [40 h]; CONCRETO PREMEZCLADO F'C=280 kg/cm2 CON CEMENTO T-I [88.13] |  |
| A4850 |  | Pintura bituminosa |  | 8d | 2024-11-28 | 2024-12-05 | A4810 | 1d | 0d | HH [280.83 h]; PINTURA ASFALTICA [434.6] |  |
| A4890 |  | Junta de dilatación |  | 2d | 2024-11-28 | 2024-11-29 | A4810 | 24d | 6d | HH [16 h] |  |
|  | PERIODO LLUVIAS | **PERIODO DE LLUVIAS** |  |  | 2025-01-01 | 2025-04-30 |  |  |  |  |  |
| A5370 |  | Periodo de Lluvias |  | 120d | 2025-01-01 | 2025-04-30 | A2930, A1670, A1530, A7951, A7952, A7390, A7310, A7370, A7330, A7430, A7450, A6200 | 0d |  | HH [960 h] |  |
|  | 2 | **CONSTRUCCION DIQUES 2025** |  |  | 2025-03-26 | 2025-10-05 |  |  |  |  |  |
| A7960 |  | Trabajos en cantera |  | 194d | 2025-03-26 | 2025-10-05 | A5370 SS+84d, A7961 FF+5d, A7962 FF+5d | 0d |  |  |  |
| A7961 |  | Suministro de Roca |  | 153d | 2025-05-01 | 2025-09-30 | A5370 SS+120d | 0d |  |  |  |
| A7962 |  | Suministro de Roca Nueva |  | 153d | 2025-05-01 | 2025-09-30 | A5370 SS+120d | 0d |  |  |  |
|  | 6 | **I-15-3-DI** |  |  | 2025-05-01 | 2025-05-19 |  |  |  |  |  |
| A7460 |  | Inicio I-15-3-DI-67+883.31 - Entrega de terreno liberado | milestone | 0d | 2025-05-01 | 2025-05-01 | A5370 | 0d |  |  |  |
| A7470 |  | Fin I-15-3-DI-67+883.31 - Entrega de terreno liberado | milestone | 0d | 2025-05-19 | 2025-05-19 | A1930 FF | 139d |  |  |  |
|  | 1 | **DIQUE** |  |  | 2025-05-01 | 2025-05-19 |  |  |  |  |  |
|  | 1 | **Excavaciones** |  |  | 2025-05-01 | 2025-05-10 |  |  |  |  |  |
| A1840 |  | Desbroce |  | 1d | 2025-05-01 | 2025-05-01 | A7460 SS | 0d |  | Excavator [8 h]; HH [8 h] | 560 |
| A1850 |  | Excavacion de cimentación |  | 7d | 2025-05-02 | 2025-05-08 | A1840 | 0d |  | Excavator [56 h]; HH [56 h] | 3,920 |
| A1860 |  | Perfilado y conformación de plataforma de fundación |  | 2d | 2025-05-06 | 2025-05-07 | A1850 SS+4d | 1d | 0d | HH [16 h] |  |
| A1870 |  | Excavacion de uña |  | 2d | 2025-05-09 | 2025-05-10 | A1850, A1860 | 0d |  | Excavator [16 h]; HH [16 h] | 1,120 |

| ID | WBS | Activity | Type | Duration | Start | Finish | Predecessors | Total float | Free float | Resources | Cost |
| --- | --- | --- | --- | --- | --- | --- | --- | --- | --- | --- | --- |
|  | 2 | **Rellenos** |  |  | 2025-05-08 | 2025-05-09 |  |  |  |  |  |
| A1880 |  | Relleno con material granular (incluye extracción de material, zarandeo y / combinación de material) |  | 1d | 2025-05-08 | 2025-05-08 | A1860 | 1d | 0d | HH [8 h]; MONEDA [15] | 15 |
| A1890 |  | Relleno mejorado con cemento |  | 1d | 2025-05-09 | 2025-05-09 | A1880 | 1d | 0d | HH [8 h]; Relleno mejorado con Cemento [109.02] |  |
|  | 3 | **Geotextil** |  |  | 2025-05-09 | 2025-05-11 |  |  |  |  |  |
| A1910 |  | Zanja de anclaje |  | 1d | 2025-05-09 | 2025-05-09 | A1880 | 1d | 0d | HH [8 h] |  |
| A1900 |  | Instalación de geotextil 400 gr/m2 |  | 2d | 2025-05-10 | 2025-05-11 | A1910, A1890 | 1d |  | HH [16 h]; Geotextil [3750] |  |
|  | 4 | **Colocacion de Roca** |  |  | 2025-05-11 | 2025-05-19 |  |  |  |  |  |
| A1920 |  | Colocación de roca en uña |  | 5d | 2025-05-11 | 2025-05-15 | A1870, A1900 SS | 0d |  | Excavator [40 h]; HH [40 h]; Roca [1182.98 m3] | 2,800 |
| A1930 |  | Colocación de roca en talud |  | 4d | 2025-05-16 | 2025-05-19 | A1920 | 0d |  | Excavator [32 h]; HH [32 h]; Roca [649.34 m3] | 2,240 |
|  | 5 | **Transporte** |  |  | 2025-05-01 | 2025-05-18 |  |  |  |  |  |
| A6230 |  | Transporte de material orgánico (a dmo) |  | 1d | 2025-05-01 | 2025-05-01 | A1840 SS | 18d | 0d | HH [8 h] |  |
| A6240 |  | Transporte de material excedente |  | 9d | 2025-05-02 | 2025-05-10 | A1850 SS, A6230 | 18d | 1d | HH [72 h] |  |
| A6280 |  | Transporte de material seleccionado para zanja |  | 1d | 2025-05-09 | 2025-05-09 | A1910 SS | 17d | 0d | HH [8 h] |  |
| A6270 |  | Transporte de material de préstamo cantera de rio (cuerpo de terraplén) |  | 2d | 2025-05-10 | 2025-05-11 | A1890 SS, A6280 | 17d | 0d | HH [16 h] |  |
| A6260 |  | Transporte de roca |  | 7d | 2025-05-12 | 2025-05-18 | A1920 SS, A6240, A6270 | 17d | 1d | HH [56 h] |  |
|  | 7 | **I-14-1-PT** |  |  | 2025-05-20 | 2025-07-01 |  |  |  |  |  |
| A7480 |  | Inicio I-14-1-PT-68+715.78 - Entrega de terreno liberado | milestone | 0d | 2025-05-20 | 2025-05-20 | A1930 | 0d |  |  |  |
| A7490 |  | Fin I-14-1-PT-68+715.78 - Entrega de terreno liberado | milestone | 0d | 2025-07-01 | 2025-07-01 | A2060 FF, A6330 FF | 96d |  |  |  |
|  | 1 | **DIQUE** |  |  | 2025-05-20 | 2025-07-01 |  |  |  |  |  |
| A5630 |  | Solucion de interferencias INT 01 - Tipo tubo |  | 18d | 2025-05-21 | 2025-06-07 | A1940 | 2d |  | HH [144 h] |  |
| A5920 |  | Solucion de interferencias I-14-PT-CAN01 - Tipo canal |  | 18d | 2025-05-21 | 2025-06-07 | A1940 | 2d |  | HH [144 h] |  |
|  | 1 | **Excavaciones** |  |  | 2025-05-20 | 2025-06-18 |  |  |  |  |  |
| A1940 |  | Desbroce |  | 1d | 2025-05-20 | 2025-05-20 | A7480 SS | 0d |  | Excavator [8 h]; HH [8 h] | 560 |
| A1950 |  | Excavacion de cimentación |  | 20d | 2025-05-21 | 2025-06-09 | A1940 | 0d |  | Excavator [160 h]; HH [160 h] | 11,200 |
| A1960 |  | Perfilado y conformación de plataforma de fundación |  | 8d | 2025-05-26 | 2025-06-02 | A1950 SS+5d | 1d | 0d | HH [64 h] |  |
| A1970 |  | Excavacion de uña |  | 9d | 2025-06-10 | 2025-06-18 | A1950, A1960 | 0d |  | Excavator [72 h]; HH [72 h] | 5,040 |

| ID | WBS | Activity | Type | Duration | Start | Finish | Predecessors | Total float | Free float | Resources | Cost |
| --- | --- | --- | --- | --- | --- | --- | --- | --- | --- | --- | --- |
|  | 2 | **Rellenos** |  |  | 2025-05-26 | 2025-06-08 |  |  |  |  |  |
| A1980 |  | Relleno con material granular (incluye extracción de material, zarandeo y / combinación de material) |  | 5d | 2025-05-26 | 2025-05-30 | A1950 SS+5d | 2d | 0d | HH [40 h]; MONEDA [2487.99] | 2,487.99 |
| A1990 |  | Perfilado de talud del dique |  | 5d | 2025-05-26 | 2025-05-30 | A1980 SS | 123d | 0d | HH [40 h] |  |
| A2000 |  | Relleno con material seleccionado (incluye extracción de material, / zarandeo y combinación de material) en sobreex |  | 5d | 2025-05-31 | 2025-06-04 | A1980, A1990 | 123d | 3d | HH [40 h]; Cerco [943.7] |  |
| A2010 |  | Grava para drenaje |  | 4d | 2025-06-03 | 2025-06-06 | A1960 | 1d | 0d | HH [32 h]; Grava para drenaje [262.5] |  |
| A2020 |  | Relleno mejorado con cemento |  | 2d | 2025-06-07 | 2025-06-08 | A2010 | 1d |  | HH [16 h]; Relleno mejorado con Cemento [241] |  |
|  | 3 | **Geotextil** |  |  | 2025-05-27 | 2025-06-07 |  |  |  |  |  |
| A2040 |  | Zanja de anclaje |  | 2d | 2025-05-27 | 2025-05-28 | A1980 SS+1d | 2d | 0d | HH [16 h] |  |
| A2030 |  | Instalación de geotextil 400 gr/m2 |  | 10d | 2025-05-29 | 2025-06-07 | A2040 | 2d |  | HH [80 h]; Geotextil [7212] |  |
|  | 4 | **Colocacion de Roca** |  |  | 2025-05-24 | 2025-07-01 |  |  |  |  |  |
| A2050 |  | Colocación de roca en uña |  | 17d | 2025-05-24 | 2025-06-09 | A1950 SS+3d | 0d |  | Excavator [136 h]; HH [136 h]; Roca [3977.89 m3] | 9,520 |
| A2060 |  | Colocación de roca en talud |  | 22d | 2025-06-10 | 2025-07-01 | A2050, A5630, A2020, A2030, A1970 SS, A5920, A1950 | 0d |  | Excavator [176 h]; HH [176 h]; Roca [3532.44 m3] | 12,320 |
|  | 5 | **Transporte** |  |  | 2025-05-20 | 2025-07-01 |  |  |  |  |  |
| A6290 |  | Transporte de material orgánico (a dmo) |  | 1d | 2025-05-20 | 2025-05-20 | A1940 SS, A6260 | 16d | 0d | HH [8 h] |  |
| A6300 |  | Transporte de material excedente |  | 29d | 2025-05-21 | 2025-06-18 | A1950 SS, A6290 | 16d | 3d | HH [232 h] |  |
| A6320 |  | Transporte de roca |  | 39d | 2025-05-24 | 2025-07-01 | A2050 SS, A6300 SS | 13d | 0d | HH [312 h] |  |
| A6340 |  | Transporte de material seleccionado para zanja |  | 2d | 2025-05-27 | 2025-05-28 | A2040 SS | 120d | 0d | HH [16 h] |  |
| A6310 |  | Transporte de material de prestamo (afirmado) |  | 5d | 2025-05-29 | 2025-06-02 | A1980 SS, A6340 | 120d | 0d | HH [40 h] |  |
| A6330 |  | Transporte de material de préstamo cantera de rio (cuerpo de terraplén) |  | 5d | 2025-06-03 | 2025-06-07 | A2000 SS, A6310 | 120d | 24d | HH [40 h] |  |
|  | 8 | **I-14-2-PT** |  |  | 2025-07-02 | 2025-08-02 |  |  |  |  |  |
| A7500 |  | Inicio I-14-2-PT-68+432.64 - Entrega de terreno liberado | milestone | 0d | 2025-07-02 | 2025-07-02 | A2060 | 0d |  |  |  |
| A7510 |  | Fin I-14-2-PT-68+432.64 - Entrega de terreno liberado | milestone | 0d | 2025-07-28 | 2025-07-28 | A2180 FF, A6390 FF | 69d |  |  |  |
|  | 1 | **DIQUE** |  |  | 2025-07-02 | 2025-08-02 |  |  |  |  |  |
|  | 1 | **Excavaciones** |  |  | 2025-07-02 | 2025-07-16 |  |  |  |  |  |
| A2070 |  | Desbroce |  | 1d | 2025-07-02 | 2025-07-02 | A2060, A7500 SS | 0d |  | Excavator [8 h]; HH [8 h] | 560 |
| A2080 |  | Excavacion de cimentación |  | 6d | 2025-07-03 | 2025-07-08 | A2070 | 0d |  | Excavator [48 h]; HH [48 h] | 3,360 |
| A2090 |  | Perfilado y conformación de plataforma de fundación |  | 3d | 2025-07-06 | 2025-07-08 | A2080 SS+3d | 0d |  | HH [24 h] |  |
| A2100 |  | Excavacion de uña |  | 8d | 2025-07-09 | 2025-07-16 | A2080, A2090 | 0d |  | Excavator [64 h]; HH [64 h] | 4,480 |

| ID | WBS | Activity | Type | Duration | Start | Finish | Predecessors | Total float | Free float | Resources | Cost |
| --- | --- | --- | --- | --- | --- | --- | --- | --- | --- | --- | --- |
|  | 2 | **Rellenos** |  |  | 2025-07-04 | 2025-07-09 |  |  |  |  |  |
| A2110 |  | Relleno con material granular (incluye extracción de material, zarandeo y / combinación de material) |  | 2d | 2025-07-04 | 2025-07-05 | A2080 SS+1d | 6d | 0d | HH [16 h]; MONEDA [969] | 969 |
| A2120 |  | Perfilado de talud del dique |  | 1d | 2025-07-05 | 2025-07-05 | A2110 SS+1d | 7d | 0d | HH [8 h] |  |
| A2130 |  | Relleno con material seleccionado (incluye extracción de material, / zarandeo y combinación de material) en sobreex |  | 2d | 2025-07-06 | 2025-07-07 | A2110, A2120 | 7d | 0d | HH [16 h]; Cerco [421.44] |  |
| A2140 |  | Relleno mejorado con cemento |  | 2d | 2025-07-08 | 2025-07-09 | A2130 | 7d |  | HH [16 h]; Relleno mejorado con Cemento [178] |  |
|  | 3 | **Geotextil** |  |  | 2025-07-06 | 2025-07-10 |  |  |  |  |  |
| A2160 |  | Zanja de anclaje |  | 1d | 2025-07-06 | 2025-07-06 | A2110 | 6d | 0d | HH [8 h] |  |
| A2150 |  | Instalación de geotextil 400 gr/m2 |  | 4d | 2025-07-07 | 2025-07-10 | A2160 | 6d |  | HH [32 h]; Geotextil [5866] |  |
|  | 4 | **Colocacion de Roca** |  |  | 2025-07-06 | 2025-07-28 |  |  |  |  |  |
| A2170 |  | Colocación de roca en uña |  | 11d | 2025-07-06 | 2025-07-16 | A2080 SS+3d | 0d |  | Excavator [88 h]; HH [88 h]; Roca [3150.28 m3] | 6,160 |
| A2180 |  | Colocación de roca en talud |  | 12d | 2025-07-17 | 2025-07-28 | A2170, A2100, A2140, A2150 | 0d |  | Excavator [96 h]; HH [96 h]; Roca [2382.6 m3] | 6,720 |
|  | 5 | **Transporte** |  |  | 2025-07-02 | 2025-08-02 |  |  |  |  |  |
| A6350 |  | Transporte de material orgánico (a dmo) |  | 1d | 2025-07-02 | 2025-07-02 | A2070 SS, A6320 | 13d | 0d | HH [8 h] |  |
| A6360 |  | Transporte de material excedente |  | 13d | 2025-07-03 | 2025-07-15 | A2080 SS, A6350 | 13d | 3d | HH [104 h] |  |
| A6370 |  | Transporte de material de prestamo (afirmado) |  | 2d | 2025-07-04 | 2025-07-05 | A2110 SS | 90d | 1d | HH [16 h] |  |
| A6380 |  | Transporte de roca |  | 28d | 2025-07-06 | 2025-08-02 | A2170 SS, A6360 SS | 10d | 0d | HH [224 h] |  |
| A6400 |  | Transporte de material seleccionado para zanja |  | 1d | 2025-07-06 | 2025-07-06 | A2160 SS | 89d | 0d | HH [8 h] |  |
| A6390 |  | Transporte de material de préstamo cantera de rio (cuerpo de terraplén) |  | 2d | 2025-07-07 | 2025-07-08 | A2130 SS, A6370, A6400 | 89d | 20d | HH [16 h] |  |
|  | 9 | **I-13A-PT** |  |  | 2025-07-29 | 2025-08-28 |  |  |  |  |  |
| A7520 |  | Inicio I-13A-PT-71+388.29 - Entrega de terreno liberado | milestone | 0d | 2025-07-29 | 2025-07-29 | A2180 | 0d |  |  |  |
| A7530 |  | Fin I-13A-PT-71+388.29 - Entrega de terreno liberado | milestone | 0d | 2025-08-28 | 2025-08-28 | A2310 FF+1d | 38d |  |  |  |
|  | 1 | **DIQUE** |  |  | 2025-07-29 | 2025-08-27 |  |  |  |  |  |
| A5670 |  | Solucion de interferencias INT 01 - Tipo tubo |  | 13d | 2025-07-29 | 2025-08-10 | A2190 SS | 5d |  | HH [104 h] |  |
|  | 1 | **Excavaciones** |  |  | 2025-07-29 | 2025-08-15 |  |  |  |  |  |
| A2190 |  | Desbroce |  | 1d | 2025-07-29 | 2025-07-29 | A7520 SS | 0d |  | Excavator [8 h]; HH [8 h] | 560 |
| A2200 |  | Excavacion de cimentación |  | 11d | 2025-07-30 | 2025-08-09 | A2190 | 0d |  | Excavator [88 h]; HH [88 h] | 6,160 |
| A2210 |  | Perfilado y conformación de plataforma de fundación |  | 7d | 2025-08-02 | 2025-08-08 | A2200 SS+3d | 1d |  | HH [56 h] |  |
| A2220 |  | Excavacion de uña |  | 6d | 2025-08-10 | 2025-08-15 | A2200, A2210 | 0d |  | Excavator [48 h]; HH [48 h] | 3,360 |

| ID | WBS | Activity | Type | Duration | Start | Finish | Predecessors | Total float | Free float | Resources | Cost |
| --- | --- | --- | --- | --- | --- | --- | --- | --- | --- | --- | --- |
|  | 2 | **Rellenos** |  |  | 2025-08-02 | 2025-08-10 |  |  |  |  |  |
| A2230 |  | Relleno con material granular (incluye extracción de material, zarandeo y / combinación de material) |  | 1d | 2025-08-02 | 2025-08-02 | A2200 SS+3d | 5d | 0d | HH [8 h]; MONEDA [369.21] | 369.21 |
| A2240 |  | Relleno sin compactar |  | 3d | 2025-08-02 | 2025-08-04 | A2230 SS | 5d | 0d | HH [24 h] |  |
| A2250 |  | Perfilado de talud del dique |  | 1d | 2025-08-02 | 2025-08-02 | A2230 SS | 7d | 2d | HH [8 h] |  |
| A2260 |  | Relleno con material seleccionado (incluye extracción de material, / zarandeo y combinación de material) en sobreex |  | 4d | 2025-08-05 | 2025-08-08 | A2240, A2250 | 5d | 0d | HH [32 h]; Cerco [1591.98] |  |
| A2270 |  | Relleno mejorado con cemento |  | 2d | 2025-08-09 | 2025-08-10 | A2260 | 5d |  | HH [16 h]; Relleno mejorado con Cemento [222] |  |
|  | 3 | **Geotextil** |  |  | 2025-08-02 | 2025-08-10 |  |  |  |  |  |
| A2290 |  | Zanja de anclaje |  | 1d | 2025-08-02 | 2025-08-02 | A2240 SS | 5d | 0d | HH [8 h] |  |
| A2280 |  | Instalación de geotextil 400 gr/m2 |  | 8d | 2025-08-03 | 2025-08-10 | A2290 | 5d |  | HH [64 h]; Geotextil [3946] |  |
|  | 4 | **Colocacion de Roca** |  |  | 2025-08-05 | 2025-08-27 |  |  |  |  |  |
| A2300 |  | Colocación de roca en uña |  | 11d | 2025-08-05 | 2025-08-15 | A2200 SS+6d | 0d |  | Excavator [88 h]; HH [88 h]; Roca [2693.74 m3] | 6,160 |
| A2310 |  | Colocación de roca en talud |  | 12d | 2025-08-16 | 2025-08-27 | A2300, A5670, A2220, A2270, A2280 | 0d |  | Excavator [96 h]; HH [96 h]; Roca [2283.16 m3] | 6,720 |
|  | 5 | **Transporte** |  |  | 2025-08-02 | 2025-08-27 |  |  |  |  |  |
| A6460 |  | Transporte de material seleccionado para zanja |  | 1d | 2025-08-02 | 2025-08-02 | A2290 SS | 10d | 0d | HH [8 h] |  |
| A6410 |  | Transporte de material orgánico (a dmo) |  | 1d | 2025-08-03 | 2025-08-03 | A2190 SS, A6380 | 10d | 0d | HH [8 h] |  |
| A6430 |  | Transporte de material de prestamo (afirmado) |  | 1d | 2025-08-03 | 2025-08-03 | A2230 SS, A6460 | 10d | 1d | HH [8 h] |  |
| A6420 |  | Transporte de material excedente |  | 17d | 2025-08-04 | 2025-08-20 | A2200 SS, A6410 | 10d | 1d | HH [136 h] |  |
| A6440 |  | Transporte de roca |  | 23d | 2025-08-05 | 2025-08-27 | A2300 SS, A6420 SS, A6450 SS | 9d | 0d | HH [184 h] |  |
| A6450 |  | Transporte de material de préstamo cantera de rio (cuerpo de terraplén) |  | 4d | 2025-08-05 | 2025-08-08 | A2260 SS, A6430 | 9d | 0d | HH [32 h] |  |
|  | 10 | **I-12-PT** |  |  | 2025-08-28 | 2025-09-30 |  |  |  |  |  |
| A7540 |  | Inicio I-12-PT-83+262.94 - Entrega de terreno liberado | milestone | 0d | 2025-08-28 | 2025-08-28 | A2310 | 0d |  |  |  |
| A7550 |  | Fin I-12-PT-83+262.94 - Entrega de terreno liberado | milestone | 0d | 2025-09-30 | 2025-09-30 | A2420 FF, A6500 FF | 0d |  |  |  |
|  | 1 | **DIQUE** |  |  | 2025-08-28 | 2025-09-30 |  |  |  |  |  |
|  | 1 | **Excavaciones** |  |  | 2025-08-28 | 2025-09-21 |  |  |  |  |  |
| A2320 |  | Desbroce |  | 2d | 2025-08-28 | 2025-08-29 | A7540 SS | 0d |  | Excavator [16 h]; HH [16 h] | 1,120 |
| A2330 |  | Excavacion de cimentación |  | 12d | 2025-08-30 | 2025-09-10 | A2320 | 0d |  | Excavator [96 h]; HH [96 h] | 6,720 |
| A2340 |  | Perfilado y conformación de plataforma de fundación |  | 11d | 2025-08-31 | 2025-09-10 | A2330 SS+1d | 9d | 0d | HH [88 h] |  |
| A2350 |  | Excavacion de uña |  | 11d | 2025-09-11 | 2025-09-21 | A2330, A2340 | 9d |  | Excavator [88 h]; HH [88 h] | 6,160 |

| ID | WBS | Activity | Type | Duration | Start | Finish | Predecessors | Total float | Free float | Resources | Cost |
| --- | --- | --- | --- | --- | --- | --- | --- | --- | --- | --- | --- |
|  | 2 | **Rellenos** |  |  | 2025-09-01 | 2025-09-14 |  |  |  |  |  |
| A2360 |  | Relleno con material granular (incluye extracción de material, zarandeo y / combinación de material) |  | 12d | 2025-09-01 | 2025-09-12 | A2330 SS+2d | 2d | 0d | HH [96 h]; MONEDA [5654.25] | 5,654.25 |
| A2370 |  | Perfilado de talud del dique |  | 8d | 2025-09-05 | 2025-09-12 | A2360 SS+4d | 21d | 0d | HH [64 h] |  |
| A2380 |  | Relleno mejorado con cemento |  | 2d | 2025-09-13 | 2025-09-14 | A2360, A2370 | 21d |  | HH [16 h]; Relleno mejorado con Cemento [164] |  |
|  | 3 | **Geotextil** |  |  | 2025-09-06 | 2025-09-21 |  |  |  |  |  |
| A2400 |  | Zanja de anclaje |  | 3d | 2025-09-06 | 2025-09-08 | A2360 SS+5d | 2d | 0d | HH [24 h] |  |
| A2390 |  | Instalación de geotextil 400 gr/m2 |  | 13d | 2025-09-09 | 2025-09-21 | A2400 | 9d |  | HH [104 h]; Geotextil [6362.83] |  |
|  | 4 | **Colocacion de Roca** |  |  | 2025-09-06 | 2025-09-30 |  |  |  |  |  |
| A2410 |  | Colocación de roca en uña |  | 12d | 2025-09-06 | 2025-09-17 | A2330 SS+7d | 0d |  | Excavator [80 h]; HH [80 h]; Roca [4933.41 m3] | 5,600 |
| A2420 |  | Colocación de roca en talud |  | 13d | 2025-09-18 | 2025-09-30 | A2410, A2390 SS, A2330, A2350 FF | 0d |  | Excavator [104 h]; HH [104 h]; Roca [5504.74 m3] | 7,280 |
|  | 5 | **Transporte** |  |  | 2025-08-28 | 2025-09-28 |  |  |  |  |  |
| A6470 |  | Transporte de material orgánico (a dmo) |  | 2d | 2025-08-28 | 2025-08-29 | A2320 SS, A6440 | 9d | 0d | HH [16 h] |  |
| A6480 |  | Transporte de material excedente |  | 25d | 2025-08-30 | 2025-09-23 | A2330 SS, A6470 | 9d | 7d | HH [200 h] |  |
| A6490 |  | Transporte de material de prestamo (afirmado) |  | 12d | 2025-09-01 | 2025-09-12 | A2360 SS | 7d | 5d | HH [96 h] |  |
| A6500 |  | Transporte de roca |  | 23d | 2025-09-06 | 2025-09-28 | A2410 SS, A6480 SS, A6520 SS | 2d |  | HH [184 h] |  |
| A6520 |  | Transporte de material seleccionado para zanja |  | 3d | 2025-09-06 | 2025-09-08 | A2400 SS, A6490 SS | 2d | 0d | HH [24 h] |  |
|  | 26 | **I-02-DI - Muro** |  |  | 2025-05-01 | 2025-06-23 |  |  |  |  |  |
| A7560 |  | Inicio I-02-DI-131+367.15 - Entrega de terreno liberado | milestone | 0d | 2025-05-01 | 2025-05-01 | A5370 | 0d |  |  |  |
| A7570 |  | Fin I-02-DI-131+367.15 - Entrega de terreno liberado | milestone | 0d | 2025-06-23 | 2025-06-23 | A4290 FF, A5740 FF, A4310 FF | 104d | 98d |  |  |
|  | 1 | **DIQUE** |  |  | 2025-05-01 | 2025-06-23 |  |  |  |  |  |
| A5740 |  | Solucion de interferencias INT 01 - Tipo tubo |  | 28d | 2025-05-01 | 2025-05-28 | A4170 SS | 12d | 0d | HH [224 h] |  |
|  | 1 | **Excavaciones** |  |  | 2025-05-01 | 2025-05-25 |  |  |  |  |  |
| A4170 |  | Desbroce |  | 1d | 2025-05-01 | 2025-05-01 | A7560 SS | 0d |  | Excavator [8 h]; HH [8 h] | 560 |
| A4180 |  | Excavacion de cimentación |  | 11d | 2025-05-02 | 2025-05-12 | A4170 | 0d |  | Excavator [88 h]; HH [88 h] | 6,160 |
| A4190 |  | Perfilado y conformación de plataforma de fundación |  | 8d | 2025-05-05 | 2025-05-12 | A4180 SS+3d | 0d |  | HH [64 h] |  |
| A4200 |  | Excavacion de uña |  | 13d | 2025-05-13 | 2025-05-25 | A4180, A4190 | 0d |  | Excavator [104 h]; HH [104 h] | 7,280 |

| ID | WBS | Activity | Duration | Start | Finish | Predecessors | Total float | Free float | Resources | Cost |
| --- | --- | --- | --- | --- | --- | --- | --- | --- | --- | --- |
|  | 2 | **Rellenos** |  | 2025-05-01 | 2025-06-07 |  |  |  |  |  |
| A4220 |  | Perfilado de talud del dique | 1d | 2025-05-01 | 2025-05-01 | A5740 SS | 12d | 0d | HH [8 h] |  |
| A4230 |  | Relleno con material seleccionado (incluye extracción de material, / zarandeo y combinación de material) en sobreex | 1d | 2025-05-02 | 2025-05-02 | A4220 | 12d | 0d | HH [8 h]; Cerco [224] |  |
| A4240 |  | Relleno mejorado con cemento | 1d | 2025-05-03 | 2025-05-03 | A4230 | 14d | 2d | HH [8 h]; Relleno mejorado con Cemento [106.16] |  |
| A4250 |  | Relleno estructural | 9d | 2025-05-30 | 2025-06-07 | A5340, A5300, A4230 | 110d | 0d | HH [72 h]; Relleno estructural [3048] |  |
|  | 3 | **Geotextil** |  | 2025-05-03 | 2025-05-26 |  |  |  |  |  |
| A4270 |  | Zanja de anclaje | 3d | 2025-05-03 | 2025-05-05 | A4230 | 12d | 0d | HH [24 h] |  |
| A4260 |  | Instalación de geotextil 400 gr/m2 | 21d | 2025-05-06 | 2025-05-26 | A4270, A4240 | 12d |  | HH [168 h]; Geotextil [10450.1] |  |
|  | 4 | **Colocacion de Roca** |  | 2025-05-26 | 2025-06-23 |  |  |  |  |  |
| A4280 |  | Colocación de roca en uña | 13d | 2025-05-26 | 2025-06-07 | A4200, A5300 | 0d |  | Excavator [104 h]; HH [104 h]; Roca [5210.1 m3] | 7,280 |
| A4290 |  | Colocación de roca en talud | 16d | 2025-06-08 | 2025-06-23 | A4280, A4260 | 0d |  | Excavator [128 h]; HH [128 h]; Roca [2801.02 m3] | 8,960 |
| A4300 |  | Concreto f'c=210kg/cm2 para recebado | 8d | 2025-06-08 | 2025-06-15 | A4290 SS, A4250 | 110d | 0d | HH [64 h] |  |
| A4310 |  | Colocación de roca en corona | 2d | 2025-06-16 | 2025-06-17 | A4300 | 110d | 6d | Excavator [16 h]; HH [16 h]; Roca [156 m3] | 1,120 |
|  | 5 | **Transporte** |  | 2025-05-01 | 2025-06-22 |  |  |  |  |  |
| A6530 |  | Transporte de material orgánico (a dmo) | 1d | 2025-05-01 | 2025-05-01 | A4170 SS | 43d | 0d | HH [8 h] |  |
| A6540 |  | Transporte de material excedente | 24d | 2025-05-02 | 2025-05-25 | A4180 SS, A6530 | 43d | 0d | HH [192 h] |  |
| A6570 |  | Transporte de material de préstamo cantera de rio (cuerpo de terraplén) | 1d | 2025-05-02 | 2025-05-02 | A4230 SS | 63d | 0d | HH [8 h] |  |
| A6580 |  | Transporte de material seleccionado para zanja | 3d | 2025-05-03 | 2025-05-05 | A4270 SS, A6570 | 63d | 20d | HH [24 h] |  |
| A6560 |  | Transporte de roca | 28d | 2025-05-26 | 2025-06-22 | A4280 SS, A6540, A6580 | 43d | 4d | HH [224 h] |  |
|  | 5 | **MURO** |  | 2025-05-03 | 2025-05-29 |  |  |  |  |  |
| A5240 |  | Concreto de nivelacion (f'c=100 kg/cm2) | 8d | 2025-05-03 | 2025-05-10 | A4180 SS+1d | 1d | 0d | HH [64 h]; CONCRETO PREMEZCLADO F'C=100 kg/cm2 CON CEMENTO T-I [144] |  |
| A5270 |  | Encofrado y desencofrado caravista | 15d | 2025-05-04 | 2025-05-18 | A5240 SS+1d | 4d | 0d | HH [120 h] |  |
| A5330 |  | Tubo pvc - d=4'' | 2d | 2025-05-05 | 2025-05-06 | A5240 SS+2d | 5d | 4d | HH [16 h] |  |
| A5280 |  | Encofrado y desencofrado cara oculta | 17d | 2025-05-06 | 2025-05-22 | A5270 SS+2d | 4d | 0d | HH [136 h]; MADERA TORNILLO [5150 und] |  |
| A5290 |  | Acero de refuerzo f'y=4200kg/cm2 | 18d | 2025-05-06 | 2025-05-23 | A5280 SS | 4d | 0d | HH [144 h]; acero [105853] |  |
| A5250 |  | Concreto clase c (f'c=280 kg/cm2) premezclado - cimientos reforzados | 11d | 2025-05-08 | 2025-05-18 | A5290 SS+2d | 4d | 0d | HH [88 h]; CONCRETO PREMEZCLADO F'C=280 kg/cm2 CON CEMENTO T-I [642]; PIEDRA CHANCADA [674.64]; ARENA GRUESA [652.72]; CEMENTO PORTLAND TIPO I (42.5 kg) [10945.4] |  |
| A5320 |  | Tubo pvc - d=6'' | 4d | 2025-05-11 | 2025-05-14 | A5240, A5330 | 1d | 0d | HH [32 h] |  |
| A5260 |  | Concreto clase c (f'c=280 kg/cm2) premezclado - muros de contencion | 11d | 2025-05-15 | 2025-05-25 | A5250 SS+7d | 4d | 0d | HH [88 h]; CONCRETO PREMEZCLADO F'C=280 kg/cm2 CON CEMENTO T-I [427] |  |
| A5310 |  | Geocompuesto de drenaje | 5d | 2025-05-15 | 2025-05-19 | A5240, A5320 | 1d | 0d | HH [40 h] |  |
| A5300 |  | Pintura bituminosa | 5d | 2025-05-20 | 2025-05-24 | A5260 SS+2d, A5310 | 1d |  | HH [1064.11 h]; PINTURA ASFALTICA [1218] |  |
| A5340 |  | Junta de dilatación | 4d | 2025-05-26 | 2025-05-29 | A5260 | 12d | 0d | HH [32 h] |  |

| ID | WBS | Activity | Type | Duration | Start | Finish | Predecessors | Total float | Free float | Resources | Cost |
| --- | --- | --- | --- | --- | --- | --- | --- | --- | --- | --- | --- |
|  | 4 | **RAMPA DESEMBARCO CANOTAJE** |  |  | 2025-05-02 | 2025-06-20 |  |  |  |  |  |
| A5470 |  | Rampa de desembarco canotaje |  | 50d | 2025-05-02 | 2025-06-20 | A4170 | 107d | 101d | HH [3440 h] |  |
|  | 22 | **I-04-1-DI- Muro** |  |  | 2025-06-14 | 2025-08-01 |  |  |  |  |  |
| A7640 |  | Inicio I-04-1-DI-113+105.55 - Entrega de terreno liberado | milestone | 0d | 2025-07-05 | 2025-07-05 | A4290 FS+11d | 0d |  |  |  |
| A7650 |  | Fin I-04-1-DI-113+105.55 - Entrega de terreno liberado | milestone | 0d | 2025-08-01 | 2025-08-01 | A5350 FF, A3660 FF | 65d | 59d |  |  |
|  | 1 | **DIQUE** |  |  | 2025-07-05 | 2025-08-01 |  |  |  |  |  |
| A7260 |  | Solucion de interferencias TL01 - Tipo tubo |  | 15d | 2025-07-09 | 2025-07-23 | A3640 | 1d |  | HH [120 h] |  |
| A7290 |  | Solucion de interferencias I-04-DI-CAN01 I-04-DI-CAN02- Tipo canal |  | 15d | 2025-07-09 | 2025-07-23 | A3640 | 1d |  | HH [120 h] |  |
|  | 1 | **Excavaciones** |  |  | 2025-07-05 | 2025-07-24 |  |  |  |  |  |
| A3640 |  | Desbroce |  | 4d | 2025-07-05 | 2025-07-08 | A7640 SS | 0d |  | Excavator [32 h]; HH [32 h] | 2,240 |
| A3650 |  | Excavación de cimentación |  | 16d | 2025-07-09 | 2025-07-24 | A3640 | 0d |  | Excavator [128 h]; HH [128 h] | 8,960 |
|  | 2 | **Rellenos** |  |  | 2025-07-05 | 2025-07-16 |  |  |  |  |  |
| A3660 |  | Relleno estructural |  | 12d | 2025-07-05 | 2025-07-16 | A5120 SS+2d, A5080 SS+2d | 81d | 16d | HH [96 h]; Relleno estructural [3882] |  |
|  | 4 | **Colocacion de Roca** |  |  | 2025-07-25 | 2025-08-01 |  |  |  |  |  |
| A5350 |  | Colocacion de roca en uña |  | 8d | 2025-07-25 | 2025-08-01 | A5080, A5090, A3650, A7260, A7290 | 0d |  | Excavator [64 h]; HH [64 h]; Roca [1448.1 m3] | 4,480 |
|  | 5 | **Transporte** |  |  | 2025-07-05 | 2025-07-31 |  |  |  |  |  |
| A6770 |  | Transporte de material orgánico (a dmo) |  | 1d | 2025-07-05 | 2025-07-05 | A3640 SS | 52d | 3d | HH [8 h] |  |
| A6780 |  | Transporte de material excedente |  | 13d | 2025-07-09 | 2025-07-21 | A3650 SS, A6770 | 49d | 3d | HH [104 h] |  |
| A6800 |  | Transporte de roca |  | 7d | 2025-07-25 | 2025-07-31 | A5350 SS, A6780 | 46d | 1d | HH [56 h] |  |
|  | 3 | **MURO** |  |  | 2025-06-14 | 2025-07-12 |  |  |  |  |  |
| A5020 |  | Concreto de nivelacion (f'c=100 kg/cm2) |  | 5d | 2025-06-14 | 2025-06-18 | A5340 FS+15d | 12d | 0d | HH [40 h]; CONCRETO PREMEZCLADO F'C=100 kg/cm2 CON CEMENTO T-I [90] |  |
| A5050 |  | Encofrado y desencofrado caravista |  | 12d | 2025-06-15 | 2025-06-26 | A5020 SS+1d | 93d | 0d | HH [96 h] |  |
| A5030 |  | Concreto clase c (f'c=280 kg/cm2) premezclado - cimientos reforzados |  | 10d | 2025-06-19 | 2025-06-28 | A5020 | 15d | 0d | HH [80 h]; CONCRETO PREMEZCLADO F'C=280 kg/cm2 CON CEMENTO T-I [431.38]; PIEDRA CHANCADA [476.88]; ARENA GRUESA [461.38]; CEMENTO PORTLAND TIPO I (42.5 kg) [7736.84] |  |
| A5070 |  | Acero de refuerzo f'y=4200kg/cm2 |  | 14d | 2025-06-19 | 2025-07-02 | A5020 | 12d | 0d | HH [112 h]; acero [97343] |  |
| A5110 |  | Tubo pvc - d=4'' |  | 2d | 2025-06-19 | 2025-06-20 | A5020 | 23d | 0d | HH [16 h] |  |
| A5060 |  | Encofrado y desencofrado cara oculta |  | 12d | 2025-06-21 | 2025-07-02 | A5050 SS+6d | 93d | 3d | HH [96 h]; MADERA TORNILLO [3967 und] |  |
| A5100 |  | Tubo pvc - d=6'' |  | 6d | 2025-06-21 | 2025-06-26 | A5020, A5110 | 23d | 0d | HH [48 h] |  |
| A5040 |  | Concreto clase c (f'c=280 kg/cm2) premezclado - muros de contencion |  | 10d | 2025-06-24 | 2025-07-03 | A5030 SS+5d | 15d | 0d | HH [80 h]; CONCRETO PREMEZCLADO F'C=280 kg/cm2 CON CEMENTO T-I [395] |  |
| A5120 |  | Junta de dilatación |  | 7d | 2025-06-24 | 2025-06-30 | A5040 SS, A5060 SS | 90d | 9d | HH [56 h] |  |
| A5090 |  | Geocompuesto de drenaje |  | 5d | 2025-06-27 | 2025-07-01 | A5020, A5100 | 23d |  | HH [40 h] |  |
| A5080 |  | Pintura bituminosa |  | 10d | 2025-07-03 | 2025-07-12 | A5040 SS+6d, A5070 | 12d | 0d | HH [770.41 h]; PINTURA ASFALTICA [924] |  |

| ID | WBS | Activity | Type | Duration | Start | Finish | Predecessors | Total float | Free float | Resources | Cost |
| --- | --- | --- | --- | --- | --- | --- | --- | --- | --- | --- | --- |
|  | 16 | **I-07-DI** |  |  | 2025-08-02 | 2025-09-24 |  |  |  |  |  |
| A7660 |  | Inicio I-07-DI-111+063.06 - Entrega de terreno liberado | milestone | 0d | 2025-08-02 | 2025-08-02 | A5350 | 0d |  |  |  |
| A7670 |  | Fin I-07-DI-111+063.06 - Entrega de terreno liberado | milestone | 0d | 2025-09-24 | 2025-09-24 | A3270 FF, A6880 FF | 11d |  |  |  |
|  | 1 | **DIQUE** |  |  | 2025-08-02 | 2025-09-24 |  |  |  |  |  |
| A5720 |  | Solucion de interferencias INT 01 - Tipo tubo |  | 23d | 2025-08-04 | 2025-08-26 | A3150 | 5d |  | HH [184 h] |  |
|  | 1 | **Excavaciones** |  |  | 2025-08-02 | 2025-08-22 |  |  |  |  |  |
| A3150 |  | Desbroce |  | 2d | 2025-08-02 | 2025-08-03 | A7660 SS | 0d |  | Excavator [16 h]; HH [16 h] | 1,120 |
| A3160 |  | Excavación de cimentación |  | 8d | 2025-08-04 | 2025-08-11 | A3150 | 0d |  | Excavator [64 h]; HH [64 h] | 4,480 |
| A3170 |  | Perfilado y conformación de plataforma de fundación |  | 4d | 2025-08-08 | 2025-08-11 | A3160 SS+4d | 9d | 0d | HH [32 h] |  |
| A3180 |  | Excavación de uña |  | 11d | 2025-08-12 | 2025-08-22 | A3160, A3170 | 9d |  | Excavator [88 h]; HH [88 h] | 6,160 |
|  | 2 | **Rellenos** |  |  | 2025-08-06 | 2025-08-15 |  |  |  |  |  |
| A3190 |  | Relleno con material granular (incluye extracción de material, zarandeo y / combinación de material) |  | 2d | 2025-08-06 | 2025-08-07 | A3160 SS+2d | 10d | 0d | HH [16 h]; MONEDA [2001] | 2,001 |
| A3200 |  | Perfilado de talud del dique |  | 2d | 2025-08-06 | 2025-08-07 | A3190 SS | 10d | 0d | HH [16 h] |  |
| A3210 |  | Relleno con material seleccionado (incluye extracción de material, / zarandeo y combinación de material) en sobreex |  | 6d | 2025-08-08 | 2025-08-13 | A3200 | 10d | 0d | HH [48 h]; Cerco [1075.84] |  |
| A3220 |  | Grava para drenaje |  | 1d | 2025-08-14 | 2025-08-14 | A3210 | 16d | 0d | HH [8 h]; Grava para drenaje [91.84] |  |
| A3230 |  | Relleno mejorado con cemento |  | 1d | 2025-08-15 | 2025-08-15 | A3220 | 16d |  | HH [8 h]; Relleno mejorado con Cemento [157.83] |  |
|  | 3 | **Geotextil** |  |  | 2025-08-08 | 2025-08-21 |  |  |  |  |  |
| A3250 |  | Zanja de anclaje |  | 3d | 2025-08-08 | 2025-08-10 | A3210 SS | 10d | 0d | HH [24 h] |  |
| A3240 |  | Instalación de geotextil 400 gr/m2 |  | 11d | 2025-08-11 | 2025-08-21 | A3250 | 10d |  | HH [88 h]; Geotextil [5617.85] |  |
|  | 4 | **Colocacion de Roca** |  |  | 2025-08-12 | 2025-09-24 |  |  |  |  |  |
| A3260 |  | Colocación de roca en uña |  | 20d | 2025-08-12 | 2025-08-31 | A3160 | 0d |  | Excavator [160 h]; HH [160 h]; Roca [4595.05 m3] | 11,200 |
| A3270 |  | Colocación de roca en talud |  | 24d | 2025-09-01 | 2025-09-24 | A3260, A5720, A3180, A3240, A3230 | 0d |  | Excavator [192 h]; HH [192 h]; Roca [3795.63 m3] | 13,440 |
|  | 5 | **Transporte** |  |  | 2025-08-02 | 2025-09-24 |  |  |  |  |  |
| A6830 |  | Transporte de material orgánico (a dmo) |  | 1d | 2025-08-02 | 2025-08-02 | A3150 SS, A6800 | 45d | 1d | HH [8 h] |  |
| A6840 |  | Transporte de material excedente |  | 19d | 2025-08-04 | 2025-08-22 | A3160 SS, A6830 | 44d | 4d | HH [152 h] |  |
| A6850 |  | Transporte de material de prestamo (afirmado) |  | 2d | 2025-08-06 | 2025-08-07 | A3190 SS | 50d | 0d | HH [16 h] |  |
| A6870 |  | Transporte de material de préstamo cantera de rio (cuerpo de terraplén) |  | 6d | 2025-08-08 | 2025-08-13 | A3210 SS, A6840 SS, A6850 | 50d | 0d | HH [48 h] |  |
| A6860 |  | Transporte de roca |  | 44d | 2025-08-12 | 2025-09-24 | A3260 SS | 5d | 0d | HH [352 h] |  |
| A6880 |  | Transporte de material seleccionado para zanja |  | 3d | 2025-08-14 | 2025-08-16 | A3250 SS, A6870 | 50d | 39d | HH [24 h] |  |

| ID | WBS | Activity | Type | Duration | Start | Finish | Predecessors | Total float | Free float | Resources | Cost |
| --- | --- | --- | --- | --- | --- | --- | --- | --- | --- | --- | --- |
|  | 28 | **I-06-2-CM** |  |  | 2025-09-21 | 2025-09-30 |  |  |  |  |  |
| A7680 |  | Inicio I-06-2-CM-111+243.74 - Entrega de terreno liberado | milestone | 0d | 2025-09-21 | 2025-09-21 | A3270 SS+20d | 0d |  |  |  |
| A7690 |  | Fin I-06-2-CM-111+243.74 - Entrega de terreno liberado | milestone | 0d | 2025-09-30 | 2025-09-30 | A3530 FF, A6940 FF | 0d |  |  |  |
|  | 1 | **DIQUE** |  |  | 2025-09-21 | 2025-09-30 |  |  |  |  |  |
|  | 1 | **Excavaciones** |  |  | 2025-09-21 | 2025-09-25 |  |  |  |  |  |
| A3430 |  | Desbroce |  | 1d | 2025-09-21 | 2025-09-21 | A7680 SS | 0d |  | Excavator [8 h]; HH [8 h] | 560 |
| A3440 |  | Excavación de cimentación |  | 2d | 2025-09-22 | 2025-09-23 | A3430 | 0d |  | Excavator [8 h]; HH [8 h] | 560 |
| A3450 |  | Perfilado y conformación de plataforma de fundación |  | 1d | 2025-09-22 | 2025-09-22 | A3440 SS | 1d |  | HH [8 h] |  |
| A3460 |  | Excavación de uña |  | 2d | 2025-09-24 | 2025-09-25 | A3440, A3450 | 0d |  | Excavator [8 h]; HH [8 h] | 560 |
|  | 2 | **Relleno** |  |  | 2025-09-24 | 2025-09-26 |  |  |  |  |  |
| A3470 |  | Relleno con material granular (incluye extracción de material, zarandeo y / combinación de material) |  | 1d | 2025-09-24 | 2025-09-24 | A3440 | 2d | 0d | HH [8 h]; MONEDA [262.67] | 262.67 |
| A3480 |  | Perfilado de talud del dique |  | 1d | 2025-09-25 | 2025-09-25 | A3470 | 2d | 0d | HH [8 h] |  |
| A3490 |  | Relleno mejorado con cemento |  | 1d | 2025-09-26 | 2025-09-26 | A3470, A3480 | 2d |  | HH [8 h]; Relleno mejorado con Cemento [28.94] |  |
|  | 3 | **Geotextil** |  |  | 2025-09-25 | 2025-09-26 |  |  |  |  |  |
| A3510 |  | Zanja de anclaje |  | 1d | 2025-09-25 | 2025-09-25 | A3470 | 2d | 0d | HH [8 h] |  |
| A3500 |  | Instalación de geotextil 400 gr/m2 |  | 1d | 2025-09-26 | 2025-09-26 | A3510 | 2d |  | HH [8 h]; Geotextil [802.28] |  |
|  | 4 | **Colocacion de Roca** |  |  | 2025-09-26 | 2025-09-30 |  |  |  |  |  |
| A3520 |  | Colocación de roca en uña |  | 3d | 2025-09-26 | 2025-09-28 | A3460 | 0d |  | Excavator [16 h]; HH [16 h]; Roca [568.13 m3] | 1,120 |
| A3530 |  | Colocación de roca en talud |  | 2d | 2025-09-29 | 2025-09-30 | A3520, A3500, A3490 | 0d |  | Excavator [8 h]; HH [8 h]; Roca [454.54 m3] | 560 |
|  | 5 | **Transporte** |  |  | 2025-09-25 | 2025-09-26 |  |  |  |  |  |
| A6890 |  | Transporte de material orgánico (a dmo) |  | 1d | 2025-09-25 | 2025-09-25 | A3430 SS, A6860 | 5d | 0d | HH [8 h] |  |
| A6900 |  | Transporte de material excedente |  | 2d | 2025-09-25 | 2025-09-26 | A3440 SS, A6890 SS | 5d | 0d | HH [16 h] |  |
| A6910 |  | Transporte de material de prestamo |  | 1d | 2025-09-25 | 2025-09-25 | A3470 SS, A6900 SS | 5d | 1d | HH [8 h] |  |
| A6920 |  | Transporte de roca |  | 1d | 2025-09-26 | 2025-09-26 | A3520 SS, A6910 SS | 4d | 0d | HH [8 h] |  |
| A6940 |  | Transporte de material seleccionado para zanja |  | 1d | 2025-09-26 | 2025-09-26 | A3510 SS, A6920 SS | 4d |  | HH [8 h] |  |

| ID | WBS | Activity | Type | Duration | Start | Finish | Predecessors | Total float | Free float | Resources | Cost |
| --- | --- | --- | --- | --- | --- | --- | --- | --- | --- | --- | --- |
|  | 13 | **I-09-PT** |  |  | 2025-05-25 | 2025-06-26 |  |  |  |  |  |
| A7400 |  | Inicio I-09-PT-93+520.79 - Entrega de terreno liberado | milestone | 0d | 2025-05-25 | 2025-05-25 | A5370 FS+24d | 0d |  |  |  |
| A7410 |  | Fin I-09-PT-93+520.79 - Entrega de terreno liberado | milestone | 0d | 2025-06-26 | 2025-06-26 | A2760 FF, A2800 FF, A6060 FF, A6080 FF | 101d |  |  |  |
|  | 1 | **DIQUE** |  |  | 2025-05-25 | 2025-06-26 |  |  |  |  |  |
| A5690 |  | Solucion de interferencias INT 01 - Tipo tubo |  | 11d | 2025-05-26 | 2025-06-05 | A2670 | 1d |  | HH [88 h] |  |
|  | 1 | **Excavaciones** |  |  | 2025-05-25 | 2025-06-13 |  |  |  |  |  |
| A2670 |  | Desbroce |  | 1d | 2025-05-25 | 2025-05-25 | A7400 SS | 0d |  | Excavator [8 h]; HH [8 h] | 560 |
| A2680 |  | Excavación de cimentación |  | 11d | 2025-05-26 | 2025-06-05 | A2670 | 0d |  | Excavator [88 h]; HH [88 h] | 6,160 |
| A2690 |  | Perfilado y conformación de plataforma de fundación |  | 9d | 2025-05-28 | 2025-06-05 | A2680 SS+2d | 9d |  | HH [72 h] |  |
| A2700 |  | Excavacion de uña |  | 8d | 2025-06-06 | 2025-06-13 | A2680, A2690 SS | 0d |  | Excavator [64 h]; HH [64 h] | 4,480 |
|  | 2 | **Rellenos** |  |  | 2025-05-27 | 2025-06-13 |  |  |  |  |  |
| A2710 |  | Relleno con material granular (incluye extracción de material, zarandeo y / combinación de material) |  | 2d | 2025-05-27 | 2025-05-28 | A2680 SS+1d | 3d | 0d | HH [16 h]; MONEDA [1013.28] | 1,013.28 |
| A2720 |  | Relleno sin compactar |  | 5d | 2025-05-29 | 2025-06-02 | A2710 | 3d | 0d | HH [40 h] |  |
| A2730 |  | Perfilado de talud del dique |  | 1d | 2025-05-29 | 2025-05-29 | A2720 SS | 3d | 0d | HH [8 h] |  |
| A2740 |  | Relleno con material seleccionado (incluye extracción de material, / zarandeo y combinación de material) en sobreex |  | 1d | 2025-05-30 | 2025-05-30 | A2710 SS, A2730 | 3d | 0d | HH [8 h]; Cerco [30.85] |  |
| A2750 |  | Grava para drenaje |  | 11d | 2025-05-31 | 2025-06-10 | A2720 SS, A2740 | 3d | 0d | HH [88 h]; Grava para drenaje [5619.43] |  |
| A2760 |  | Relleno mejorado con cemento |  | 3d | 2025-06-11 | 2025-06-13 | A2750 | 114d | 13d | HH [24 h]; Relleno mejorado con Cemento [284] |  |
|  | 3 | **Geotextil** |  |  | 2025-05-31 | 2025-06-10 |  |  |  |  |  |
| A2780 |  | Zanja de anclaje |  | 2d | 2025-05-31 | 2025-06-01 | A2750 SS | 3d | 0d | HH [16 h] |  |
| A2770 |  | Instalación de geotextil 400 gr/m2 |  | 9d | 2025-06-02 | 2025-06-10 | A2780 | 3d |  | HH [72 h]; Geotextil [11203] |  |
|  | 4 | **Colocacion de Roca** |  |  | 2025-05-30 | 2025-06-26 |  |  |  |  |  |
| A2790 |  | Colocación de roca en uña |  | 8d | 2025-05-30 | 2025-06-06 | A2680 SS+4d | 0d |  | Excavator [64 h]; HH [64 h]; Roca [3615.18 m3] | 4,480 |
| A2800 |  | Colocación de roca en talud |  | 20d | 2025-06-07 | 2025-06-26 | A2790, A2770 SS+2d, A2700 SS+1d, A5690 | 0d |  | Excavator [160 h]; HH [160 h]; Roca [3544.56 m3] | 11,200 |
|  | 5 | **Transporte** |  |  | 2025-05-25 | 2025-06-26 |  |  |  |  |  |
| A6050 |  | Transporte de material orgánico (a dmo) |  | 2d | 2025-05-25 | 2025-05-26 | A2670 SS | 111d | 0d | HH [16 h] |  |
| A6060 |  | Transporte de material excedente |  | 21d | 2025-05-27 | 2025-06-16 | A2680 SS, A6050, A6070 FF | 111d | 10d | HH [168 h] |  |
| A6080 |  | Transporte de roca |  | 28d | 2025-05-30 | 2025-06-26 | A2790 SS | 101d | 0d | HH [224 h] |  |
| A6100 |  | Transporte de material seleccionado para zanja |  | 1d | 2025-05-31 | 2025-05-31 | A2780 SS | 117d | 0d | HH [8 h] |  |
| A6090 |  | Transporte de material de préstamo cantera de rio (cuerpo de terraplén) |  | 5d | 2025-06-01 | 2025-06-05 | A2710 SS, A6100 | 117d | 0d | HH [40 h] |  |
| A6070 |  | Transporte de material de prestamo (afirmado) |  | 5d | 2025-06-06 | 2025-06-10 | A2710 SS, A6090 | 117d | 6d | HH [40 h] |  |

| ID | WBS | Activity | Type | Duration | Start | Finish | Predecessors | Total float | Free float | Resources | Cost |
| --- | --- | --- | --- | --- | --- | --- | --- | --- | --- | --- | --- |
|  | 12 | **I-10-PT** |  |  | 2025-06-27 | 2025-08-14 |  |  |  |  |  |
| A7580 |  | Inicio I-10-PT-92+923.32 - Entrega de terreno liberado | milestone | 0d | 2025-06-27 | 2025-06-27 | A2800 | 0d |  |  |  |
| A7590 |  | Fin I-10-PT-92+923.32 - Entrega de terreno liberado | milestone | 0d | 2025-08-14 | 2025-08-14 | A2660 FF, A6640 FF | 52d |  |  |  |
|  | 1 | **DIQUE** |  |  | 2025-06-27 | 2025-08-14 |  |  |  |  |  |
| A5620 |  | Solucion de interferencias INT 01 - Tipo tubo |  | 21d | 2025-06-27 | 2025-07-17 | A2550 SS | 12d |  | HH [168 h] |  |
|  | 1 | **Excavaciones** |  |  | 2025-06-27 | 2025-07-16 |  |  |  |  |  |
| A2550 |  | Desbroce |  | 0d | 2025-06-27 | 2025-06-27 | A7580 SS | 0d |  | Excavator; HH |  |
| A2560 |  | Excavación de cimentación |  | 10d | 2025-06-27 | 2025-07-06 | A2550 | 0d |  | Excavator [80 h]; HH [80 h] | 5,600 |
| A2570 |  | Perfilado y conformación de plataforma de fundación |  | 7d | 2025-06-29 | 2025-07-05 | A2560 SS+2d | 1d |  | HH [56 h] |  |
| A2580 |  | Excavacion de uña |  | 10d | 2025-07-07 | 2025-07-16 | A2560, A2570 | 0d |  | Excavator [80 h]; HH [80 h] | 5,600 |
|  | 2 | **Rellenos** |  |  | 2025-07-02 | 2025-07-07 |  |  |  |  |  |
| A2590 |  | Relleno con material granular (incluye extracción de material, zarandeo y / combinación de material) |  | 1d | 2025-07-02 | 2025-07-02 | A2560 SS+5d | 12d | 0d | HH [8 h]; MONEDA [249.07] | 249.07 |
| A2600 |  | Perfilado de talud del dique |  | 1d | 2025-07-03 | 2025-07-03 | A2590 | 12d | 0d | HH [8 h] |  |
| A2610 |  | Relleno con material seleccionado (incluye extracción de material, / zarandeo y combinación de material) en sobreex |  | 2d | 2025-07-04 | 2025-07-05 | A2590, A2600 | 12d | 0d | HH [16 h]; Cerco [446.9] |  |
| A2620 |  | Relleno mejorado con cemento |  | 2d | 2025-07-06 | 2025-07-07 | A2610 | 12d | 0d | HH [16 h]; Relleno mejorado con Cemento [219] |  |
|  | 3 | **Geotextiles** |  |  | 2025-07-08 | 2025-07-17 |  |  |  |  |  |
| A2640 |  | Zanja de anclaje |  | 1d | 2025-07-08 | 2025-07-08 | A2620 | 12d | 0d | HH [8 h] |  |
| A2630 |  | Instalación de geotextil 400 gr/m2 |  | 9d | 2025-07-09 | 2025-07-17 | A2640 | 12d |  | HH [72 h]; Geotextil [4413.56] |  |
|  | 4 | **Colocacion de Roca** |  |  | 2025-07-17 | 2025-08-14 |  |  |  |  |  |
| A2650 |  | Colocación de roca en uña |  | 13d | 2025-07-17 | 2025-07-29 | A2580 | 0d |  | Excavator [104 h]; HH [104 h]; Roca [3345.78 m3] | 7,280 |
| A2660 |  | Colocación de roca en talud |  | 16d | 2025-07-30 | 2025-08-14 | A2650, A5620, A2580, A2630 | 0d |  | Excavator [128 h]; HH [128 h]; Roca [2280.75 m3] | 8,960 |
|  | 5 | **Transporte** |  |  | 2025-06-27 | 2025-08-12 |  |  |  |  |  |
| A6590 |  | Transporte de material orgánico (a dmo) |  | 1d | 2025-06-27 | 2025-06-27 | A2550 SS, A6560 | 39d | 0d | HH [8 h] |  |
| A6600 |  | Transporte de material excedente |  | 18d | 2025-06-28 | 2025-07-15 | A2560 SS, A6590 | 39d | 19d | HH [144 h] |  |
| A6610 |  | Transporte de material de prestamo (afirmado) |  | 1d | 2025-07-02 | 2025-07-02 | A2590 SS | 92d | 1d | HH [8 h] |  |
| A6630 |  | Transporte de material de préstamo cantera de rio (cuerpo de terraplén) |  | 2d | 2025-07-04 | 2025-07-05 | A2610 SS, A6610 | 91d | 2d | HH [16 h] |  |
| A6640 |  | Transporte de material seleccionado para zanja |  | 1d | 2025-07-08 | 2025-07-08 | A2640 SS, A6630 | 89d | 37d | HH [8 h] |  |
| A6620 |  | Transporte de roca |  | 27d | 2025-07-17 | 2025-08-12 | A2650 SS, A6600 SS | 20d | 2d | HH [216 h] |  |

| ID | WBS | Activity | Type | Duration | Start | Finish | Predecessors | Total float | Free float | Resources | Cost |
| --- | --- | --- | --- | --- | --- | --- | --- | --- | --- | --- | --- |
|  | 15 | **D-03-DI** |  |  | 2025-08-15 | 2025-09-10 |  |  |  |  |  |
| A7600 |  | Inicio D-03-DI-108+238.01 - Entrega de terreno liberado | milestone | 0d | 2025-08-15 | 2025-08-15 | A2660 | 0d |  |  |  |
| A7610 |  | Fin D-03-DI-108+238.01 - Entrega de terreno liberado | milestone | 0d | 2025-09-09 | 2025-09-09 | A3140 FF, A6700 FF | 26d |  |  |  |
|  | 1 | **DIQUE** |  |  | 2025-08-15 | 2025-09-10 |  |  |  |  |  |
| A5700 |  | Solucion de interferencias |  | 12d | 2025-08-15 | 2025-08-26 | A3020 SS | 6d |  | HH [96 h] |  |
|  | 1 | **Excavaciones** |  |  | 2025-08-15 | 2025-08-25 |  |  |  |  |  |
| A3020 |  | Desbroce |  | 1d | 2025-08-15 | 2025-08-15 | A7600 SS | 0d |  | Excavator [8 h]; HH [8 h] | 560 |
| A3030 |  | Excavación de cimentación |  | 4d | 2025-08-16 | 2025-08-19 | A3020 | 0d |  | Excavator [32 h]; HH [32 h] | 2,240 |
| A3040 |  | Perfilado y conformación de plataforma de fundación |  | 2d | 2025-08-17 | 2025-08-18 | A3030 SS+1d | 3d |  | HH [16 h] |  |
| A3060 |  | Excavación localizada - sobreexcavación |  | 2d | 2025-08-20 | 2025-08-21 | A3030 | 0d |  | HH [16 h] |  |
| A3050 |  | Excavacion de uña |  | 4d | 2025-08-22 | 2025-08-25 | A3030, A3040, A3060 | 0d |  | Excavator [32 h]; HH [32 h] | 2,240 |
|  | 2 | **Rellenos** |  |  | 2025-08-20 | 2025-08-22 |  |  |  |  |  |
| A3070 |  | Relleno con material granular (incluye extracción de material, zarandeo y / combinación de material) |  | 1d | 2025-08-20 | 2025-08-20 | A3030 | 4d | 0d | HH [8 h]; MONEDA [593.25] | 593.25 |
| A3080 |  | Perfilado de talud del dique |  | 1d | 2025-08-20 | 2025-08-20 | A3070 SS | 4d | 0d | HH [8 h] |  |
| A3090 |  | Relleno con material seleccionado (incluye extracción de material, / zarandeo y combinación de material) en sobreex |  | 1d | 2025-08-21 | 2025-08-21 | A3070, A3080 | 4d | 0d | HH [8 h]; Cerco [230.8] |  |
| A3100 |  | Relleno mejorado con cemento |  | 1d | 2025-08-22 | 2025-08-22 | A3090 | 4d | 0d | HH [8 h]; Relleno mejorado con Cemento [154.25] |  |
|  | 3 | **Geotextil** |  |  | 2025-08-23 | 2025-08-28 |  |  |  |  |  |
| A3120 |  | Zanja de anclaje |  | 1d | 2025-08-23 | 2025-08-23 | A3100 | 4d | 0d | HH [8 h] |  |
| A3110 |  | Instalación de geotextil 400 gr/m2 |  | 5d | 2025-08-24 | 2025-08-28 | A3120 | 4d |  | HH [40 h]; Geotextil [2914.19] |  |
|  | 4 | **Colocacion de Roca** |  |  | 2025-08-26 | 2025-09-09 |  |  |  |  |  |
| A3130 |  | Colocación de roca en uña |  | 7d | 2025-08-26 | 2025-09-01 | A3030, A3050 | 0d |  | Excavator [56 h]; HH [56 h]; Roca [1825.14 m3] | 3,920 |
| A3140 |  | Colocación de roca en talud |  | 8d | 2025-09-02 | 2025-09-09 | A3130, A5700, A3050, A3110 | 0d |  | Excavator [64 h]; HH [64 h]; Roca [1684.61 m3] | 4,480 |
|  | 5 | **Transporte** |  |  | 2025-08-15 | 2025-09-10 |  |  |  |  |  |
| A6650 |  | Transporte de material orgánico (a dmo) |  | 1d | 2025-08-15 | 2025-08-15 | A3020 SS, A6620 | 18d | 5d | HH [8 h] |  |
| A6670 |  | Transporte de material de prestamo (afirmado) |  | 1d | 2025-08-20 | 2025-08-20 | A3070 SS | 44d | 0d | HH [8 h] |  |
| A6660 |  | Transporte de material excedente |  | 8d | 2025-08-21 | 2025-08-28 | A3030 SS+5d, A6650 | 13d | 5d | HH [64 h] |  |
| A6690 |  | Transporte de material de préstamo cantera de rio (cuerpo de terraplén) |  | 1d | 2025-08-21 | 2025-08-21 | A3090 SS, A6670 | 44d | 1d | HH [8 h] |  |
| A6700 |  | Transporte de material seleccionado para zanja |  | 1d | 2025-08-23 | 2025-08-23 | A3120 SS, A6690 | 43d | 17d | HH [8 h] |  |
| A6680 |  | Transporte de roca |  | 16d | 2025-08-26 | 2025-09-10 | A3130 SS, A6660 SS | 8d | 1d | HH [128 h] |  |

| ID | WBS | Activity | Type | Duration | Start | Finish | Predecessors | Total float | Free float | Resources | Cost |
| --- | --- | --- | --- | --- | --- | --- | --- | --- | --- | --- | --- |
|  | 20 | **I-06-1-CM- Muro** |  |  | 2025-09-12 | 2025-09-29 |  |  |  |  |  |
| A7620 |  | Inicio I-06-1-CM-111+198.46 - Entrega de terreno liberado | milestone | 0d | 2025-09-12 | 2025-09-12 | A3140 FS+2d | 0d |  |  |  |
| A7630 |  | Fin I-06-1-CM-111+198.46 - Entrega de terreno liberado | milestone | 0d | 2025-09-29 | 2025-09-29 | A4900 FF, A6740 FF, A4940 FF | 0d |  |  |  |
|  | 1 | **DIQUE** |  |  | 2025-09-12 | 2025-09-23 |  |  |  |  |  |
|  | 1 | **Excavaciones** |  |  | 2025-09-12 | 2025-09-18 |  |  |  |  |  |
| A3280 |  | Desbroce |  | 2d | 2025-09-12 | 2025-09-13 | A7620 SS | 0d |  | Excavator [16 h]; HH [16 h] | 1,120 |
| A3290 |  | Excavación de cimentación |  | 5d | 2025-09-14 | 2025-09-18 | A3280 | 1d | 0d | Excavator [40 h]; HH [40 h] | 2,800 |
|  | 4 | **Colocacion de Roca** |  |  | 2025-09-16 | 2025-09-23 |  |  |  |  |  |
| A5010 |  | Colocacion de roca en uña |  | 8d | 2025-09-16 | 2025-09-23 | A3290 SS+2d | 1d | 0d | Excavator [64 h]; HH [64 h]; Roca [1755.73 m3] | 4,480 |
|  | 5 | **Transporte** |  |  | 2025-09-12 | 2025-09-23 |  |  |  |  |  |
| A6710 |  | Transporte de material orgánico (a dmo) |  | 1d | 2025-09-12 | 2025-09-12 | A3280 SS, A6680 | 7d | 1d | HH [8 h] |  |
| A6720 |  | Transporte de material excedente |  | 4d | 2025-09-14 | 2025-09-17 | A3290 SS, A6710 | 6d | 0d | HH [32 h] |  |
| A6740 |  | Transporte de roca |  | 6d | 2025-09-18 | 2025-09-23 | A5010 SS, A6720 | 6d |  | HH [48 h] |  |
|  | 3 | **MURO** |  |  | 2025-09-14 | 2025-09-29 |  |  |  |  |  |
| A4940 |  | Encofrado y desencofrado cara oculta |  | 16d | 2025-09-14 | 2025-09-29 | A3280 SS+2d | 0d |  | HH [120 h]; MADERA TORNILLO [3967 und] |  |
| A4900 |  | Concreto de nivelacion (f'c=100 kg/cm2) |  | 12d | 2025-09-17 | 2025-09-28 | A5010 SS+1d, A4940 SS | 1d |  | HH [96 h]; CONCRETO PREMEZCLADO F'C=100 kg/cm2 CON CEMENTO T-I [216] |  |
|  | 21 | **I-05-PT** |  |  | 2025-05-01 | 2025-07-06 |  |  |  |  |  |
| A7700 |  | Inicio I-05-PT-111+569.71 - Entrega de terreno liberado | milestone | 0d | 2025-05-01 | 2025-05-01 | A5370 | 0d |  |  |  |
| A7710 |  | Fin I-05-PT-111+569.71 - Entrega de terreno liberado | milestone | 0d | 2025-05-08 | 2025-05-08 | A3580 FF | 150d |  |  |  |
|  | 1 | **DIQUE** |  |  | 2025-05-01 | 2025-07-06 |  |  |  |  |  |
| A5640 |  | Solucion de interferencias INT 01 INT 02- Tipo tubo |  | 28d | 2025-05-02 | 2025-05-29 | A3540 | 12d |  | HH [224 h] |  |
|  | 1 | **Excavaciones** |  |  | 2025-05-01 | 2025-05-19 |  |  |  |  |  |
| A3540 |  | Desbroce |  | 1d | 2025-05-01 | 2025-05-01 | A7700 SS | 0d |  | Excavator [8 h]; HH [8 h] | 560 |
| A3550 |  | Excavación de cimentación |  | 5d | 2025-05-02 | 2025-05-06 | A3540 | 0d |  | Excavator [40 h]; HH [40 h] | 2,800 |
| A3560 |  | Perfilado y conformación de plataforma de fundación |  | 4d | 2025-05-02 | 2025-05-05 | A3550 SS | 1d |  | HH [32 h] |  |
| A3570 |  | Excavación de uña |  | 13d | 2025-05-07 | 2025-05-19 | A3550, A3560 | 0d |  | Excavator [104 h]; HH [104 h] | 7,280 |

| ID | WBS | Activity | Type | Duration | Start | Finish | Predecessors | Total float | Free float | Resources | Cost |
| --- | --- | --- | --- | --- | --- | --- | --- | --- | --- | --- | --- |
|  | 2 | **Rellenos** |  |  | 2025-05-07 | 2025-05-11 |  |  |  |  |  |
| A3580 |  | Relleno con material granular (incluye extracción de material, zarandeo y / combinación de material) |  | 2d | 2025-05-07 | 2025-05-08 | A3550 | 17d | 0d | HH [16 h]; MONEDA [976.54] | 976.54 |
| A3590 |  | Relleno mejorado con cemento |  | 3d | 2025-05-09 | 2025-05-11 | A3580 | 17d | 0d | HH [24 h]; Relleno mejorado con Cemento [304] |  |
|  | 3 | **Geotextil** |  |  | 2025-05-09 | 2025-05-24 |  |  |  |  |  |
| A3610 |  | Zanja de anclaje |  | 3d | 2025-05-09 | 2025-05-11 | A3580 | 17d | 0d | HH [24 h] |  |
| A3600 |  | Instalación de geotextil 400 gr/m2 |  | 13d | 2025-05-12 | 2025-05-24 | A3610, A3590 | 17d |  | HH [104 h]; Geotextil [13394.3] |  |
|  | 4 | **Colocacion de Roca** |  |  | 2025-05-20 | 2025-07-05 |  |  |  |  |  |
| A3620 |  | Colocación de roca en uña |  | 22d | 2025-05-20 | 2025-06-10 | A3570 | 0d |  | Excavator [184 h]; HH [176 h]; Roca [5424.11 m3] | 12,880 |
| A3630 |  | Colocación de roca en talud |  | 25d | 2025-06-11 | 2025-07-05 | A3620, A5640, A3600 | 0d |  | Excavator [200 h]; HH [200 h]; Roca [4425.74 m3] | 14,000 |
|  | 5 | **Transporte** |  |  | 2025-05-01 | 2025-07-06 |  |  |  |  |  |
| A6950 |  | Transporte de material orgánico (a dmo) |  | 1d | 2025-05-01 | 2025-05-01 | A3540 SS | 29d | 0d | HH [8 h] |  |
| A6960 |  | Transporte de material excedente |  | 18d | 2025-05-02 | 2025-05-19 | A3550 SS, A6950 | 29d | 0d | HH [144 h] |  |
| A6970 |  | Transporte de material de prestamo (afirmado) |  | 2d | 2025-05-07 | 2025-05-08 | A3580 SS | 35d | 0d | HH [16 h] |  |
| A6990 |  | Transporte de material de préstamo cantera de rio (cuerpo de terraplén) |  | 2d | 2025-05-09 | 2025-05-10 | A3580 SS, A6970 | 35d | 0d | HH [16 h] |  |
| A7000 |  | Transporte de material seleccionado para zanja |  | 3d | 2025-05-11 | 2025-05-13 | A3610 SS, A6990 | 35d | 6d | HH [24 h] |  |
| A6980 |  | Transporte de roca |  | 48d | 2025-05-20 | 2025-07-06 | A3620 SS, A6960, A7000 | 29d | 0d | HH [384 h] |  |
|  | 23 | **I-04-2-DI** |  |  | 2025-06-20 | 2025-07-16 |  |  |  |  |  |
| A7720 |  | Inicio I-04-2-DI-113+202.93 - Entrega de terreno liberado | milestone | 0d | 2025-06-20 | 2025-06-20 | A3630 SS+9d | 0d |  |  |  |
| A7730 |  | Fin I-04-2-DI-113+202.93 - Entrega de terreno liberado | milestone | 0d | 2025-07-08 | 2025-07-08 | A3880 FF | 89d |  |  |  |
|  | 1 | **DIQUE** |  |  | 2025-06-20 | 2025-07-16 |  |  |  |  |  |
| A5730 |  | Solucion de interferencias |  | 8d | 2025-06-21 | 2025-06-28 | A3790 | 4d |  | HH [64 h] |  |
|  | 1 | **Excavaciones** |  |  | 2025-06-20 | 2025-06-29 |  |  |  |  |  |
| A3790 |  | Desbroce |  | 1d | 2025-06-20 | 2025-06-20 | A7720 SS | 0d |  | Excavator [8 h]; HH [8 h] | 560 |
| A3800 |  | Excavación de cimentación |  | 5d | 2025-06-21 | 2025-06-25 | A3790 | 0d |  | Excavator [40 h]; HH [40 h] | 2,800 |
| A3810 |  | Perfilado y conformación de plataforma de fundación |  | 3d | 2025-06-23 | 2025-06-25 | A3800 SS+2d | 3d | 0d | HH [24 h] |  |
| A3820 |  | Excavación de uña |  | 4d | 2025-06-26 | 2025-06-29 | A3800, A3810 | 3d |  | Excavator [32 h]; HH [32 h] | 2,240 |

| ID | WBS | Activity | Type | Duration | Start | Finish | Predecessors | Total float | Free float | Resources | Cost |
| --- | --- | --- | --- | --- | --- | --- | --- | --- | --- | --- | --- |
|  | 2 | **Rellenos** |  |  | 2025-06-23 | 2025-06-25 |  |  |  |  |  |
| A3830 |  | Relleno con material granular (incluye extracción de material, zarandeo y / combinación de material) |  | 1d | 2025-06-23 | 2025-06-23 | A3800 SS+2d | 5d | 0d | HH [8 h]; MONEDA [79.37] | 79.37 |
| A3840 |  | Relleno mejorado con cemento |  | 2d | 2025-06-24 | 2025-06-25 | A3830 | 7d |  | HH [16 h]; Relleno mejorado con Cemento [164] |  |
|  | 3 | **Geotextil** |  |  | 2025-06-24 | 2025-06-27 |  |  |  |  |  |
| A3850 |  | Instalación de geotextil 400 gr/m2 |  | 4d | 2025-06-24 | 2025-06-27 | A3860 SS | 5d |  | HH [32 h]; Geotextil [2187.95] |  |
| A3860 |  | Zanja de anclaje |  | 1d | 2025-06-24 | 2025-06-24 | A3830 | 5d | 0d | HH [8 h] |  |
|  | 4 | **Colocacion de Roca** |  |  | 2025-06-26 | 2025-07-08 |  |  |  |  |  |
| A3870 |  | Colocación de roca en uña |  | 7d | 2025-06-26 | 2025-07-02 | A3800 | 0d |  | Excavator [56 h]; HH [56 h]; Roca [1685.88 m3] | 3,920 |
| A3880 |  | Colocación de roca en talud |  | 6d | 2025-07-03 | 2025-07-08 | A3870, A5730, A3820, A3840, A3850 | 0d |  | Excavator [48 h]; HH [48 h]; Roca [1088.12 m3] | 3,360 |
|  | 5 | **Transporte** |  |  | 2025-06-23 | 2025-07-16 |  |  |  |  |  |
| A7030 |  | Transporte de material de prestamo (afirmado) |  | 1d | 2025-06-23 | 2025-06-23 | A3830 SS | 38d | 0d | HH [8 h] |  |
| A7050 |  | Transporte de material de préstamo cantera de rio (cuerpo de terraplén) |  | 2d | 2025-06-24 | 2025-06-25 | A3830 SS, A7030 | 38d | 0d | HH [16 h] |  |
| A7060 |  | Transporte de material seleccionado para zanja |  | 1d | 2025-06-24 | 2025-06-24 | A3860 SS, A7050 SS | 38d | 1d | HH [8 h] |  |
| A7040 |  | Transporte de roca |  | 13d | 2025-06-26 | 2025-07-08 | A3870 SS, A7060 | 37d | 8d | HH [104 h] |  |
| A7010 |  | Transporte de material orgánico (a dmo) |  | 1d | 2025-07-07 | 2025-07-07 | A3790 SS, A6980 | 29d | 0d | HH [8 h] |  |
| A7020 |  | Transporte de material excedente |  | 9d | 2025-07-08 | 2025-07-16 | A3800 SS, A7010 | 29d | 0d | HH [72 h] |  |
|  | 24 | **I-03-PT- Muro** |  |  | 2025-07-09 | 2025-07-28 |  |  |  |  |  |
| A7740 |  | Inicio I-03-PT-131+362.06 - Entrega de terreno liberado | milestone | 0d | 2025-07-09 | 2025-07-09 | A3880 | 0d |  |  |  |
| A7750 |  | Fin I-03-PT-131+362.06 - Entrega de terreno liberado | milestone | 0d | 2025-07-28 | 2025-07-28 | A5360 FF | 69d | 63d |  |  |
|  | 1 | **DIQUE** |  |  | 2025-07-09 | 2025-07-28 |  |  |  |  |  |
|  | 1 | **Excavaciones** |  |  | 2025-07-09 | 2025-07-11 |  |  |  |  |  |
| A3890 |  | Desbroce |  | 1d | 2025-07-09 | 2025-07-09 | A7740 SS | 0d |  | Excavator [8 h]; HH [8 h] | 560 |
| A3900 |  | Excavación de cimentación |  | 1d | 2025-07-10 | 2025-07-10 | A3890 | 0d |  | Excavator [8 h]; HH [8 h] | 560 |
| A3910 |  | Excavación de uña |  | 1d | 2025-07-11 | 2025-07-11 | A3900 | 16d |  | Excavator [8 h]; HH [8 h] | 560 |

| ID | WBS | Activity | Type | Duration | Start | Finish | Predecessors | Total float | Free float | Resources | Cost |
| --- | --- | --- | --- | --- | --- | --- | --- | --- | --- | --- | --- |
|  | 2 | **Rellenos** |  |  | 2025-07-28 | 2025-07-28 |  |  |  |  |  |
| A3920 |  | Relleno con material seleccionado (incluye extracción de material, / zarandeo y combinación de material) en sobreex |  | 1d | 2025-07-28 | 2025-07-28 | A5190, A5230 | 20d | 0d | HH [8 h]; Cerco [91.47] |  |
|  | 4 | **Colocacion de Roca** |  |  | 2025-07-28 | 2025-07-28 |  |  |  |  |  |
| A5360 |  | Colocación de roca en uña |  | 1d | 2025-07-28 | 2025-07-28 | A5190, A3910 | 0d |  | Excavator [8 h]; HH [8 h]; Roca [42 m3] | 560 |
|  | 5 | **Transporte** |  |  | 2025-07-17 | 2025-07-28 |  |  |  |  |  |
| A7070 |  | Transporte de material orgánico (a dmo) |  | 1d | 2025-07-17 | 2025-07-17 | A3890 SS, A7020, A7040 | 29d | 0d | HH [8 h] |  |
| A7080 |  | Transporte de material excedente |  | 1d | 2025-07-18 | 2025-07-18 | A3900 SS, A7070 | 29d | 9d | HH [8 h] |  |
| A7090 |  | Transporte de material de prestamo (afirmado) |  | 1d | 2025-07-28 | 2025-07-28 | A3920 SS, A7080 | 20d | 0d | HH [8 h] |  |
| A7100 |  | Transporte de roca |  | 1d | 2025-07-28 | 2025-07-28 | A5360 SS, A7090 SS | 20d | 0d | HH [8 h] |  |
|  | 3 | **MURO** |  |  | 2025-07-11 | 2025-07-27 |  |  |  |  |  |
| A5130 |  | Concreto Ciclopeo (f'c=280 kg/cm2) + 30%PG. |  | 6d | 2025-07-11 | 2025-07-16 | A3900 | 0d |  | HH [48 h]; CONCRETO PREMEZCLADO F'C=280 kg/cm2 CON CEMENTO T-I [108] |  |
| A5160 |  | Encofrado y desencofrado caravista |  | 5d | 2025-07-12 | 2025-07-16 | A5130 SS+1d | 6d | 0d | HH [40 h] |  |
| A5170 |  | Encofrado y desencofrado cara oculta |  | 6d | 2025-07-12 | 2025-07-17 | A5160 SS | 6d |  | HH [48 h]; MADERA TORNILLO [663 und] |  |
| A5180 |  | Acero de refuerzo f'y=4200kg/cm2 |  | 7d | 2025-07-17 | 2025-07-23 | A5130 | 0d |  | HH [56 h]; acero [26281] |  |
| A5220 |  | Tubo pvc - d=4'' |  | 1d | 2025-07-17 | 2025-07-17 | A5130 | 7d | 0d | HH [8 h] |  |
| A5210 |  | Tubo pvc - d=6'' |  | 1d | 2025-07-18 | 2025-07-18 | A5130, A5220 | 7d | 0d | HH [8 h] |  |
| A5200 |  | Geocompuesto de drenaje |  | 2d | 2025-07-19 | 2025-07-20 | A5130, A5210 | 7d |  | HH [16 h] |  |
| A5150 |  | Concreto clase c (f'c=280 kg/cm2) premezclado - muros de contencion |  | 2d | 2025-07-24 | 2025-07-25 | A5130 FS+1d, A5170, A5180 | 0d |  | HH [16 h]; CONCRETO PREMEZCLADO F'C=280 kg/cm2 CON CEMENTO T-I [9.69]; PIEDRA CHANCADA [5.45]; ARENA GRUESA [5.28]; CEMENTO PORTLAND TIPO I (42.5 kg) [88.47] |  |
| A5190 |  | Pintura bituminosa |  | 2d | 2025-07-26 | 2025-07-27 | A5150, A5200 SS | 0d |  | HH [27.01 h]; PINTURA ASFALTICA [182] |  |
| A5230 |  | Junta de dilatación |  | 2d | 2025-07-26 | 2025-07-27 | A5150 | 20d | 0d | HH [16 h] |  |
|  | 25 | **D-01-DI** |  |  | 2025-07-29 | 2025-09-03 |  |  |  |  |  |
| A7760 |  | Inicio D-01-DI-131+584.72 - Entrega de terreno liberado | milestone | 0d | 2025-07-29 | 2025-07-29 | A5360 | 0d |  |  |  |
| A7770 |  | Fin D-01-DI-131+584.72 - Entrega de terreno liberado | milestone | 0d | 2025-09-01 | 2025-09-01 | A4160 FF | 34d |  |  |  |
|  | 1 | **DIQUE** |  |  | 2025-07-29 | 2025-09-03 |  |  |  |  |  |
| A5660 |  | Solucion de interferencias INT 01 INT 02 - Tipo tubo |  | 9d | 2025-07-30 | 2025-08-07 | A4040 | 7d |  | HH [72 h] |  |

| ID | WBS | Activity | Type | Duration | Start | Finish | Predecessors | Total float | Free float | Resources | Cost |
| --- | --- | --- | --- | --- | --- | --- | --- | --- | --- | --- | --- |
|  | 1 | **Excavaciones** |  |  | 2025-07-29 | 2025-08-20 |  |  |  |  |  |
| A4040 |  | Desbroce |  | 1d | 2025-07-29 | 2025-07-29 | A7760 SS | 0d |  | Excavator [8 h]; HH [8 h] | 560 |
| A4050 |  | Excavación de cimentación |  | 14d | 2025-07-30 | 2025-08-12 | A4040 | 0d |  | Excavator [112 h]; HH [112 h] | 7,840 |
| A4060 |  | Perfilado y conformación de plataforma de fundación |  | 8d | 2025-08-05 | 2025-08-12 | A4050 SS+6d | 2d | 0d | HH [64 h] |  |
| A4070 |  | Excavación de uña |  | 8d | 2025-08-13 | 2025-08-20 | A4050, A4060 | 2d |  | Excavator [64 h]; HH [64 h] | 4,480 |
|  | 2 | **Rellenos** |  |  | 2025-08-04 | 2025-08-13 |  |  |  |  |  |
| A4080 |  | Relleno con material granular (incluye extracción de material, zarandeo y / combinación de material) |  | 6d | 2025-08-04 | 2025-08-09 | A4050 SS+5d | 1d | 0d | HH [48 h]; MONEDA [3572.24] | 3,572.24 |
| A4110 |  | Relleno con material seleccionado (incluye extracción de material, / zarandeo y combinación de material) en sobreex |  | 4d | 2025-08-05 | 2025-08-08 | A4080 SS+1d | 1d | 0d | HH [32 h]; Cerco [879.66] |  |
| A4120 |  | Grava para drenaje |  | 6d | 2025-08-06 | 2025-08-11 | A4110 SS+1d | 1d | 0d | HH [48 h]; Grava para drenaje [432] |  |
| A4100 |  | Perfilado de talud del dique |  | 3d | 2025-08-08 | 2025-08-10 | A4080 SS+4d | 2d | 1d | HH [24 h] |  |
| A4090 |  | Relleno sin compactar |  | 1d | 2025-08-12 | 2025-08-12 | A4120, A4100 | 1d | 0d | HH [8 h] |  |
| A4130 |  | Relleno mejorado con cemento |  | 1d | 2025-08-13 | 2025-08-13 | A4080, A4090 | 1d |  | HH [8 h]; Relleno mejorado con Cemento [303.24] |  |
|  | 3 | **Geotextil** |  |  | 2025-08-04 | 2025-08-13 |  |  |  |  |  |
| A4140 |  | Instalación de geotextil 400 gr/m2 |  | 10d | 2025-08-04 | 2025-08-13 | A4080 SS | 1d |  | HH [80 h]; Geotextil [5059.04] |  |
|  | 4 | **Colocacion de Roca** |  |  | 2025-08-08 | 2025-09-01 |  |  |  |  |  |
| A4150 |  | Colocación de roca en uña |  | 7d | 2025-08-08 | 2025-08-14 | A4050 SS+9d | 0d |  | Excavator [56 h]; HH [56 h]; Roca [3598.51 m3] | 3,920 |
| A4160 |  | Colocación de roca en talud |  | 18d | 2025-08-15 | 2025-09-01 | A4150, A5660, A4070 SS, A4130, A4140 | 0d |  | Excavator [144 h]; HH [144 h]; Roca [3318.72 m3] | 10,080 |
|  | 5 | **Transporte** |  |  | 2025-07-29 | 2025-09-03 |  |  |  |  |  |
| A7130 |  | Transporte de material orgánico (a dmo) |  | 1d | 2025-07-29 | 2025-07-29 | A4040 SS, A7100 | 20d | 0d | HH [8 h] |  |
| A7140 |  | Transporte de material excedente |  | 22d | 2025-07-30 | 2025-08-20 | A4050 SS, A7130 | 20d | 14d | HH [176 h] |  |
| A7150 |  | Transporte de material de prestamo (afirmado) |  | 7d | 2025-08-04 | 2025-08-10 | A4080 SS | 32d | 1d | HH [56 h] |  |
| A7170 |  | Transporte de material de préstamo cantera de rio (cuerpo de terraplén) |  | 5d | 2025-08-05 | 2025-08-09 | A4110 SS, A7150 SS | 31d | 25d | HH [40 h] |  |
| A7160 |  | Transporte de roca |  | 27d | 2025-08-08 | 2025-09-03 | A4150 SS | 6d | 0d | HH [216 h] |  |
|  | 27 | **I-01-PT** |  |  | 2025-09-02 | 2025-09-30 |  |  |  |  |  |
| A7780 |  | Inicio I-01-PT-132+360.07 - Entrega de terreno liberado | milestone | 0d | 2025-09-02 | 2025-09-02 | A4160 | 0d |  |  |  |
| A7790 |  | Fin I-01-PT-132+360.07 - Entrega de terreno liberado | milestone | 0d | 2025-09-30 | 2025-09-30 | A4710 FF, A7200 FF, A7220 FF | 0d |  |  |  |

| ID | WBS | Activity | Duration | Start | Finish | Predecessors | Total float | Free float | Resources | Cost |
| --- | --- | --- | --- | --- | --- | --- | --- | --- | --- | --- |
|  | 1 | **DIQUE** |  | 2025-09-02 | 2025-09-30 |  |  |  |  |  |
| A5650 |  | Solucion de interferencias INT 01 INT 02- Tipo tubo | 18d | 2025-09-03 | 2025-09-20 | A4620 | 2d |  | HH [144 h] |  |
|  | 1 | **Excavaciones** |  | 2025-09-02 | 2025-09-22 |  |  |  |  |  |
| A4620 |  | Desbroce | 1d | 2025-09-02 | 2025-09-02 | A7780 SS | 0d |  | Excavator [8 h]; HH [8 h] | 560 |
| A4630 |  | Excavación de cimentación | 12d | 2025-09-03 | 2025-09-14 | A4620 | 0d |  | Excavator [96 h]; HH [96 h] | 6,720 |
| A4640 |  | Perfilado y conformación de plataforma de fundación | 7d | 2025-09-08 | 2025-09-14 | A4630 SS+5d | 0d |  | HH [56 h] |  |
| A4650 |  | Excavación de uña | 8d | 2025-09-15 | 2025-09-22 | A4630, A4640 | 0d |  | Excavator [64 h]; HH [64 h] | 4,480 |
|  | 2 | **Rellenos** |  | 2025-09-04 | 2025-09-08 |  |  |  |  |  |
| A4660 |  | Relleno con material granular (incluye extracción de material, zarandeo y | 2d | 2025-09-04 | 2025-09-05 | A4630 SS+1d | 3d | 0d | HH [16 h]; MONEDA [788.38] | 788.38 |
| A4670 |  | Relleno mejorado con cemento | 3d | 2025-09-06 | 2025-09-08 | A4660 | 5d | 0d | HH [24 h]; Relleno mejorado con Cemento [209] |  |
|  | 3 | **Geotextil** |  | 2025-09-06 | 2025-09-17 |  |  |  |  |  |
| A4690 |  | Zanja de anclaje | 3d | 2025-09-06 | 2025-09-08 | A4660 | 3d | 0d | HH [24 h] |  |
| A4680 |  | Instalación de geotextil 400 gr/m2 | 9d | 2025-09-09 | 2025-09-17 | A4690, A4670 | 5d |  | HH [72 h]; Geotextil [4278.19] |  |
|  | 4 | **Colocacion de Roca** |  | 2025-09-11 | 2025-09-30 |  |  |  |  |  |
| A4700 |  | Colocación de roca en uña | 12d | 2025-09-11 | 2025-09-22 | A4630 SS+8d | 0d |  | Excavator [96 h]; HH [96 h]; Roca [3268.22 m3] | 6,720 |
| A4710 |  | Colocación de roca en talud | 8d | 2025-09-23 | 2025-09-30 | A4700, A5650, A4680, A4650 | 0d |  | Excavator [64 h]; HH [64 h]; Roca [1769.98 m3] | 4,480 |
|  | 5 | **Transporte** |  | 2025-09-04 | 2025-09-30 |  |  |  |  |  |
| A7190 |  | Transporte de material orgánico (a dmo) | 1d | 2025-09-04 | 2025-09-04 | A4620 SS, A7160, A7140, A7170 | 6d | 0d | HH [8 h] |  |
| A7210 |  | Transporte de material de prestamo (afirmado) | 2d | 2025-09-04 | 2025-09-05 | A4660 SS | 3d | 0d | HH [16 h] |  |
| A7200 |  | Transporte de material excedente | 20d | 2025-09-05 | 2025-09-24 | A4630 SS, A7190 | 6d |  | HH [160 h] |  |
| A7240 |  | Transporte de material seleccionado para zanja | 2d | 2025-09-06 | 2025-09-07 | A4690 SS, A7210 | 3d |  | HH [16 h] |  |
| A7220 |  | Transporte de roca | 20d | 2025-09-11 | 2025-09-30 | A4700 SS, A7240 | 0d |  | HH [160 h] |  |
